# USB Flash Drive_03152012

Schedule from MS Project, 2012-02-23 to 2012-08-24, costs in $, A marks actual dates.

## Calendars

- Standard: Mon-Fri 08:00-12:00, 13:00-17:00; Sat-Sun off.

## Resources

| Resource | Rate |
| --- | --- |
| Product Manager | 60 |
| VP of MKTG | 100 |
| Project Manager | 60 |
| ENGR | 55 |
| Operations | 60 |
| Mechanical ENGR | 50 |
| Procurement | 60 |
| CEO | 200 |
| Packaging ENGR | 50 |
| Product ENGR | 50 |
| PCB Fabricator | 40 |
| ODM/CM | 70 |
| Product MKTG | 60 |
| Outside vendor | 30 |
| Outside Cert Lab | 50 |
| Planning | 60 |
| CONSULTANT |  |
| Administrative |  |

## Schedule

| ID | WBS | Task | Type | Duration | Start | Finish | Predecessors | Complete | Remaining | Total slack | Resources | Work | Actual work | Cost | Actual cost | Deliverable |
| --- | --- | --- | --- | --- | --- | --- | --- | --- | --- | --- | --- | --- | --- | --- | --- | --- |
| 1 | 1 | **USB Flash Drive** |  | 132d | 2012-02-23 A | 2012-08-24 |  | 12% | 116.53d | 0d |  | 3216h | 512h | 170,720 | 33,920 |  |
| 2 | 1.1 | **Phase 0 (Business Case)** |  | 5d | 2012-02-23 A | 2012-02-29 A |  | 100% |  |  |  | 32h | 32h | 2,240 | 2,240 |  |
| 3 | 1.1.1 | MRD |  | 1d | 2012-02-23 A | 2012-02-23 A |  | 100% |  |  | Product Manager | 8h | 8h | 480 | 480 |  |
| 4 | 1.1.2 | Marketing Review |  | 1d | 2012-02-24 A | 2012-02-24 A | 3 | 100% |  |  | Product Manager | 8h | 8h | 480 | 480 |  |
| 5 | 1.1.3 | Marketing Approval | milestone | 0d | 2012-02-24 A | 2012-02-24 A | 4 | 100% |  |  | Product Manager |  |  |  |  |  |
| 6 | 1.1.4 | **Phase 0 Gate** |  | 1d | 2012-02-29 A | 2012-02-29 A |  | 100% |  |  |  | 16h | 16h | 1,280 | 1,280 |  |
| 7 | 1.1.4.1 | Review & approve |  | 1d | 2012-02-29 A | 2012-02-29 A | 5 | 100% |  |  | Product Manager; VP of MKTG | 16h | 16h | 1,280 | 1,280 | MRD |
| 8 | 1.2 | **Phase 1 (Planning)** |  | 74d | 2012-03-01 A | 2012-06-12 A |  | 100% |  |  |  | 480h | 480h | 31,680 | 31,680 |  |
| 9 | 1.2.1 | Internal Kick Off Meeting |  | 1d | 2012-03-01 A | 2012-03-01 A | 7 | 100% |  |  | Project Manager | 8h | 8h | 480 | 480 |  |
| 10 | 1.2.2 | **Requirements** |  | 65d | 2012-03-02 A | 2012-05-31 A |  | 100% |  |  |  | 312h | 312h | 18,200 | 18,200 |  |
| 11 | 1.2.2.1 | **PRD** |  | 7d | 2012-03-07 A | 2012-03-15 A |  | 100% |  |  |  | 80h | 80h | 4,600 | 4,600 |  |
| 12 | 1.2.2.1.1 | Generate PRD |  | 5d | 2012-03-07 A | 2012-03-13 A | 9 | 100% |  |  | Project Manager; ENGR | 48h | 48h | 2,760 | 2,760 |  |
| 13 | 1.2.2.1.2 | Internal review |  | 2d | 2012-03-14 A | 2012-03-15 A | 12 | 100% |  |  | ENGR; Project Manager | 32h | 32h | 1,840 | 1,840 |  |
| 14 | 1.2.2.1.3 | Internal approval | milestone | 0d | 2012-03-15 A | 2012-03-15 A | 13 | 100% |  |  | Project Manager; VP of MKTG |  |  |  |  | PRD |
| 15 | 1.2.2.2 | **Industrial Design** |  | 17d | 2012-03-02 A | 2012-03-26 A |  | 100% |  |  |  | 40h | 40h | 2,320 | 2,320 |  |
| 16 | 1.2.2.2.1 | Contractor Selection |  | 2d | 2012-03-02 A | 2012-03-22 A | 9 | 100% |  |  | Operations; Project Manager | 16h | 16h | 960 | 960 |  |
| 17 | 1.2.2.2.2 | Initial Industrial Design |  | 1d | 2012-03-23 A | 2012-03-23 A | 16 | 100% |  |  | Mechanical ENGR | 8h | 8h | 400 | 400 |  |
| 18 | 1.2.2.2.3 | Review |  | 1d | 2012-03-26 A | 2012-03-26 A | 17 | 100% |  |  | Project Manager; Operations | 16h | 16h | 960 | 960 |  |
| 19 | 1.2.2.3 | **Outsourcing - Suppliers/Partners Selection** |  | 65d | 2012-03-02 A | 2012-05-31 A |  | 100% |  |  |  | 192h | 192h | 11,280 | 11,280 |  |
| 20 | 1.2.2.3.1 | **RFQ process** |  | 65d | 2012-03-02 A | 2012-05-31 A |  | 100% |  |  |  | 192h | 192h | 11,280 | 11,280 |  |
| 21 | 1.2.2.3.1.1 | Generate List of Potential Partners |  | 1d | 2012-03-02 A | 2012-03-02 A | 9 | 100% |  |  | Procurement | 8h | 8h | 480 | 480 |  |
| 22 | 1.2.2.3.1.2 | Suppliers/Partners Review |  | 4d | 2012-03-05 A | 2012-03-27 A | 21 | 100% |  |  | Project Manager; Procurement | 32h | 32h | 1,920 | 1,920 |  |
| 23 | 1.2.2.3.1.3 | Issue RFQs including PRD |  | 1d | 2012-03-28 A | 2012-03-28 A | 14, 22 | 100% |  |  | Procurement | 8h | 8h | 480 | 480 | RFQ COMPLETE |
| 24 | 1.2.2.3.1.4 | **ODM Quote completed** |  | 34d | 2012-03-29 A | 2012-05-15 A |  | 100% |  |  |  | 48h | 48h | 2,840 | 2,840 |  |
| 25 | 1.2.2.3.1.4.1 | Review Financial Terms |  | 1d | 2012-03-29 A | 2012-03-29 A | 23 | 100% |  |  | Procurement | 8h | 8h | 480 | 480 |  |
| 26 | 1.2.2.3.1.4.2 | Review Technical Capabilities |  | 2d | 2012-03-30 A | 2012-05-14 A | 23 | 100% |  |  | ENGR; Project Manager | 16h | 16h | 920 | 920 |  |
| 27 | 1.2.2.3.1.4.3 | Review Production Capabilities |  | 1d | 2012-03-29 A | 2012-03-29 A | 23 | 100% |  |  | Project Manager; Operations | 16h | 16h | 960 | 960 |  |
| 28 | 1.2.2.3.1.4.4 | ODM/CM Selection |  | 1d | 2012-05-15 A | 2012-05-15 A | 25, 26, 27 | 100% |  |  | Procurement | 8h | 8h | 480 | 480 | ODM/CM AWARD |
| 29 | 1.2.2.3.1.5 | Supplier Kick off Meeting |  | 2d | 2012-05-16 A | 2012-05-29 A | 14, 18, 28 | 100% |  |  | ENGR; Project Manager | 16h | 16h | 920 | 920 |  |

| ID | WBS | Task | Type | Duration | Start | Finish | Predecessors | Complete | Resources | Work | Actual work | Cost | Actual cost | Deliverable |
| --- | --- | --- | --- | --- | --- | --- | --- | --- | --- | --- | --- | --- | --- | --- |
| 30 | 1.2.2.3.1.6 | **Contractor Quote Completed** |  | 4d | 2012-03-02 A | 2012-03-07 A |  | 100% |  | 56h | 56h | 3,240 | 3,240 |  |
| 31 | 1.2.2.3.1.6.1 | **SOW** |  | 3d | 2012-03-02 A | 2012-03-06 A |  | 100% |  | 48h | 48h | 2,760 | 2,760 |  |
| 32 | 1.2.2.3.1.6.1.1 | Generate SOW |  | 3d | 2012-03-02 A | 2012-03-06 A | 9 | 100% | ENGR; Project Manager | 48h | 48h | 2,760 | 2,760 |  |
| 33 | 1.2.2.3.1.6.1.2 | Approved | milestone | 0d | 2012-03-06 A | 2012-03-06 A | 32 | 100% | Project Manager |  |  |  |  |  |
| 34 | 1.2.2.3.1.6.2 | Review |  | 1d | 2012-03-07 A | 2012-03-07 A | 33 | 100% | Project Manager | 8h | 8h | 480 | 480 |  |
| 35 | 1.2.2.3.1.6.3 | Contractor Selection | milestone | 0d | 2012-03-07 A | 2012-03-07 A | 34 | 100% | Project Manager; Procurement |  |  |  |  |  |
| 36 | 1.2.2.3.1.7 | **Mechanical Manufacturing (Shell/Housing)** |  | 2d | 2012-05-30 A | 2012-05-31 A |  | 100% |  | 24h | 24h | 1,400 | 1,400 |  |
| 37 | 1.2.2.3.1.7.1 | Review |  | 1d | 2012-05-30 A | 2012-05-30 A | 14, 29 | 100% | ENGR | 8h | 8h | 440 | 440 |  |
| 38 | 1.2.2.3.1.7.2 | Contractor Selection | milestone | 0d | 2012-05-30 A | 2012-05-30 A | 37 | 100% | Operations; Project Manager |  |  |  |  |  |
| 39 | 1.2.2.3.1.7.3 | Kick off Meeting |  | 1d | 2012-05-31 A | 2012-05-31 A | 38 | 100% | Project Manager; Operations | 16h | 16h | 960 | 960 |  |
| 40 | 1.2.3 | **Schedule** |  | 58d | 2012-03-19 A | 2012-06-06 A |  | 100% |  | 56h | 56h | 4,000 | 4,000 |  |
| 41 | 1.2.3.1 | Set-up |  | 3d | 2012-03-19 A | 2012-03-28 A | 14 | 100% | Project Manager | 24h | 24h | 1,440 | 1,440 |  |
| 42 | 1.2.3.2 | Review |  | 3d | 2012-06-01 A | 2012-06-06 A | 29, 39, 41 | 100% | VP of MKTG; Project Manager | 32h | 32h | 2,560 | 2,560 |  |
| 43 | 1.2.3.3 | Approval | milestone | 0d | 2012-06-06 A | 2012-06-06 A | 42 | 100% | VP of MKTG |  |  |  |  | SCHEDULE |
| 44 | 1.2.4 | **BOMs/Routings** |  | 8d | 2012-05-17 A | 2012-05-28 A |  | 100% |  | 24h | 24h | 1,320 | 1,320 |  |
| 45 | 1.2.4.1 | Engineering PN Generation |  | 1d | 2012-05-18 A | 2012-05-18 A | 14 | 100% | ENGR | 8h | 8h | 440 | 440 |  |
| 46 | 1.2.4.2 | Marketing BOM (SKU) Initial Status |  | 1d | 2012-05-28 A | 2012-05-28 A | 14 | 100% | ENGR | 8h | 8h | 440 | 440 | SKU CREATED |
| 47 | 1.2.4.3 | Manufacturing BOM (Technical) Initial Status |  | 1d | 2012-05-17 A | 2012-05-17 A | 14 | 100% | ENGR | 8h | 8h | 440 | 440 |  |
| 48 | 1.2.5 | **Financial Model** |  | 72d | 2012-03-01 A | 2012-06-08 A |  | 100% |  | 32h | 32h | 1,920 | 1,920 |  |
| 49 | 1.2.5.1 | Product Development Budget |  | 1d | 2012-06-07 A | 2012-06-07 A | 28, 39, 43 | 100% | Project Manager | 8h | 8h | 480 | 480 |  |
| 50 | 1.2.5.2 | Product Cost |  | 1d | 2012-05-29 A | 2012-05-29 A | 28, 44 | 100% | Procurement | 8h | 8h | 480 | 480 |  |
| 51 | 1.2.5.3 | Marketing Plan |  | 1d | 2012-03-01 A | 2012-03-01 A | 5 | 100% | Product Manager | 8h | 8h | 480 | 480 |  |
| 52 | 1.2.5.4 | ROI/Revenue Projection |  | 1d | 2012-06-08 A | 2012-06-08 A | 47, 49, 50, 51 | 100% | Product Manager | 8h | 8h | 480 | 480 |  |
| 53 | 1.2.6 | **Phase 1 Gate** |  | 2d | 2012-06-11 A | 2012-06-12 A |  | 100% |  | 48h | 48h | 5,760 | 5,760 |  |
| 54 | 1.2.6.1 | Review & Approval |  | 2d | 2012-06-11 A | 2012-06-12 A | 14, 43, 52 | 100% | CEO; VP of MKTG; Project Manager | 48h | 48h | 5,760 | 5,760 |  |

| ID | WBS | Task | Duration | Start | Finish | Predecessors | Total slack | Free slack | Resources | Work | Cost | Deliverable |
| --- | --- | --- | --- | --- | --- | --- | --- | --- | --- | --- | --- | --- |
| 55 | 1.3 | **Phase 2 (Development)** | 132d | 2012-02-23 | 2012-08-24 |  | 0d |  |  | 2104h | 100,840 |  |
| 56 | 1.3.1 | **Documentation** | 72d | 2012-03-02 | 2012-06-11 |  | 23d |  |  | 352h | 15,040 |  |
| 57 | 1.3.1.1 | **Final Product spec to suppliers / Vendors** | 3d | 2012-03-21 | 2012-03-23 |  | 10d |  |  | 24h | 880 |  |
| 58 | 1.3.1.1.1 | Develop Spec | 1d | 2012-03-21 | 2012-03-21 | 14 | 10d | 0d | ENGR | 8h | 440 |  |
| 59 | 1.3.1.1.2 | Prepare document | 1d | 2012-03-22 | 2012-03-22 | 58 | 10d | 0d | Administrative | 8h |  |  |
| 60 | 1.3.1.1.3 | Review & Approve | 1d | 2012-03-23 | 2012-03-23 | 59 | 10d | 0d | ENGR | 8h | 440 | SPECIFICATION |
| 61 | 1.3.1.2 | **Packaging Plan** | 7d | 2012-03-02 | 2012-03-12 |  | 69d |  |  | 56h | 2,560 |  |
| 62 | 1.3.1.2.1 | Define requirements | 1d | 2012-03-02 | 2012-03-02 | 9 | 69d | 0d | Product Manager | 8h | 480 |  |
| 63 | 1.3.1.2.2 | Prepare document | 1d | 2012-03-05 | 2012-03-05 | 62 | 69d | 0d | Administrative | 8h |  |  |
| 64 | 1.3.1.2.3 | Publish Plan | 4d | 2012-03-06 | 2012-03-09 | 63 | 69d | 0d | Packaging ENGR | 32h | 1,600 |  |
| 65 | 1.3.1.2.4 | Review & Approved | 1d | 2012-03-12 | 2012-03-12 | 64 | 69d | 0d | Project Manager | 8h | 480 | PACK BRIEF |
| 66 | 1.3.1.3 | **Product Qual Plan** | 46d | 2012-03-16 | 2012-05-18 |  | 65d |  |  | 96h | 3,880 |  |
| 67 | 1.3.1.3.1 | **Compatibility Test Plan** | 46d | 2012-03-16 | 2012-05-18 |  | 65d |  |  | 32h | 1,320 |  |
| 68 | 1.3.1.3.1.1 | Prepare document | 1d | 2012-03-16 | 2012-03-16 | 14 | 65d | 0d | Administrative | 8h |  |  |
| 69 | 1.3.1.3.1.2 | Publish Plan | 1d | 2012-03-19 | 2012-03-19 | 68 | 65d | 0d | ENGR | 8h | 440 |  |
| 70 | 1.3.1.3.1.3 | Review & Approval | 2d | 2012-03-21 | 2012-05-18 | 69 | 65d | 0d | ENGR | 16h | 880 | COMPATIBILITY PLAN |
| 71 | 1.3.1.3.2 | **Reliability Plan** | 3d | 2012-03-16 | 2012-03-20 |  | 108d |  |  | 32h | 1,280 |  |
| 72 | 1.3.1.3.2.1 | Prepare document | 1d | 2012-03-16 | 2012-03-16 | 14 | 108d | 0d | Administrative | 8h |  |  |
| 73 | 1.3.1.3.2.2 | Publish Plan | 1d | 2012-03-19 | 2012-03-19 | 72 | 108d | 0d | ENGR | 8h | 440 |  |
| 74 | 1.3.1.3.2.3 | Review & Approval | 1d | 2012-03-20 | 2012-03-20 | 73 | 108d | 43d | Product ENGR; ENGR | 16h | 840 | RELIABILITY PLAN |
| 75 | 1.3.1.3.3 | **Compliance/Certification Plan** | 3d | 2012-03-16 | 2012-03-20 |  | 108d |  |  | 32h | 1,280 |  |
| 76 | 1.3.1.3.3.1 | Prepare document | 1d | 2012-03-16 | 2012-03-16 | 14 | 108d | 0d | Administrative | 8h |  |  |
| 77 | 1.3.1.3.3.2 | Publish Plan | 1d | 2012-03-19 | 2012-03-19 | 76 | 108d | 0d | ENGR | 8h | 440 |  |
| 78 | 1.3.1.3.3.3 | Review & Approval | 1d | 2012-03-20 | 2012-03-20 | 77 | 108d | 43d | ENGR; Product ENGR | 16h | 840 | COMPLIANCE PLAN |

| ID | WBS | Task | Type | Duration | Start | Finish | Predecessors | Total slack | Free slack | Resources | Work | Cost | Deliverable |
| --- | --- | --- | --- | --- | --- | --- | --- | --- | --- | --- | --- | --- | --- |
| 79 | 1.3.1.4 | **Packaging Qual Plan** |  | 5d | 2012-03-16 | 2012-03-22 |  | 106d |  |  | 40h | 1,680 |  |
| 80 | 1.3.1.4.1 | Prepare document |  | 1d | 2012-03-16 | 2012-03-16 | 14 | 106d | 0d | Administrative | 8h |  |  |
| 81 | 1.3.1.4.2 | Publish Plan |  | 3d | 2012-03-19 | 2012-03-21 | 80 | 106d | 0d | Packaging ENGR | 24h | 1,200 |  |
| 82 | 1.3.1.4.3 | Review & Approval |  | 1d | 2012-03-22 | 2012-03-22 | 81 | 106d | 41d | Project Manager | 8h | 480 | PACK QUAL PLAN |
| 83 | 1.3.1.5 | **QA Plan (IQC, OQC, OQRM, etc)** |  | 3d | 2012-03-16 | 2012-03-20 |  | 108d |  |  | 24h | 800 |  |
| 84 | 1.3.1.5.1 | Prepare document |  | 1d | 2012-03-16 | 2012-03-16 | 14 | 108d | 0d | Administrative | 8h |  |  |
| 85 | 1.3.1.5.2 | Publish Plan |  | 1d | 2012-03-19 | 2012-03-19 | 84 | 108d | 0d | Product ENGR | 8h | 400 |  |
| 86 | 1.3.1.5.3 | Review & Approval |  | 1d | 2012-03-20 | 2012-03-20 | 85 | 108d | 43d | Product ENGR | 8h | 400 | QA PLAN |
| 87 | 1.3.1.6 | **Production Plan** |  | 3d | 2012-03-16 | 2012-03-20 |  | 46d |  |  | 24h | 960 |  |
| 88 | 1.3.1.6.1 | Prepare document |  | 1d | 2012-03-16 | 2012-03-16 | 14 | 46d | 0d | Administrative | 8h |  |  |
| 89 | 1.3.1.6.2 | Publish Plan |  | 1d | 2012-03-19 | 2012-03-19 | 88 | 46d | 0d | Operations | 8h | 480 |  |
| 90 | 1.3.1.6.3 | Review & Approval |  | 1d | 2012-03-20 | 2012-03-20 | 89 | 46d | 0d | Operations | 8h | 480 | PRODUCTION PLAN |
| 91 | 1.3.1.7 | **Production Test Plan** |  | 3d | 2012-03-16 | 2012-03-20 |  | 46d |  |  | 24h | 800 |  |
| 92 | 1.3.1.7.1 | Prepare document |  | 1d | 2012-03-16 | 2012-03-16 | 14 | 46d | 0d | Administrative | 8h |  |  |
| 93 | 1.3.1.7.2 | Publish Plan |  | 1d | 2012-03-19 | 2012-03-19 | 92 | 46d | 0d | Product ENGR | 8h | 400 |  |
| 94 | 1.3.1.7.3 | Review & Approval |  | 1d | 2012-03-20 | 2012-03-20 | 93 | 46d | 0d | Product ENGR | 8h | 400 | PRODUCTION TEST |
| 95 | 1.3.1.8 | **Product Test** |  | 59d | 2012-03-21 | 2012-06-11 |  | 54d |  |  | 56h | 3,080 |  |
| 96 | 1.3.1.8.1 | Product Test Specifications |  | 1d | 2012-05-31 | 2012-05-31 | 60 | 44d | 0d | ENGR | 8h | 440 |  |
| 97 | 1.3.1.8.2 | Test Equipment |  | 2d | 2012-06-01 | 2012-06-11 | 90, 96 | 44d | 23d | Product ENGR; Operations | 16h | 880 |  |
| 98 | 1.3.1.8.3 | **Pre-lim Process** |  | 3d | 2012-03-22 | 2012-03-26 |  | 109d |  |  | 16h | 880 |  |
| 99 | 1.3.1.8.3.1 | Publish Plan |  | 2d | 2012-03-22 | 2012-03-26 | 94 | 109d | 0d | Product ENGR; Operations | 16h | 880 |  |
| 100 | 1.3.1.8.3.2 | Review & Approval | milestone | 0d | 2012-03-26 | 2012-03-26 | 99 | 109d |  | Product ENGR |  |  |  |
| 101 | 1.3.1.8.4 | **Pre-lim Program** |  | 3d | 2012-03-21 | 2012-03-23 |  | 110d |  |  | 16h | 880 |  |
| 102 | 1.3.1.8.4.1 | Publish Plan |  | 2d | 2012-03-21 | 2012-03-23 | 94 | 110d | 0d | Product ENGR; Operations | 16h | 880 |  |
| 103 | 1.3.1.8.4.2 | Review & Approval | milestone | 0d | 2012-03-23 | 2012-03-23 | 102 | 110d |  | Product ENGR |  |  |  |
| 104 | 1.3.1.9 | All qual plans prepared | milestone | 0d | 2012-03-22 | 2012-03-22 | 59, 63, 68, 72, 76, 80, 84, 88, 92 | 111d |  | Administrative |  |  |  |
| 105 | 1.3.1.10 | All Qual Plans Approved |  | 1d | 2012-05-21 | 2012-05-21 | 60, 65, 70, 74, 78, 82, 86, 90, 94 | 65d | 38d | Product ENGR | 8h | 400 |  |

| ID | WBS | Task | Type | Duration | Start | Finish | Predecessors | Total slack | Free slack | Resources | Work | Cost | Deliverable |
| --- | --- | --- | --- | --- | --- | --- | --- | --- | --- | --- | --- | --- | --- |
| 106 | 1.3.2 | **PCB** |  | 44d | 2012-03-26 | 2012-05-24 |  | 10d |  |  | 368h | 19,400 |  |
| 107 | 1.3.2.1 | Schematic Design |  | 8d | 2012-03-26 | 2012-04-04 | 60 | 10d | 0d | ENGR | 64h | 3,520 |  |
| 108 | 1.3.2.2 | PCB Layout |  | 22d | 2012-04-05 | 2012-05-04 | 107 | 10d | 0d | ENGR | 176h | 9,680 |  |
| 109 | 1.3.2.3 | Design Review |  | 3d | 2012-05-07 | 2012-05-09 | 108 | 10d | 0d | ENGR | 24h | 1,320 |  |
| 110 | 1.3.2.4 | Design For Manufacturability (DFM) - PCB |  | 2d | 2012-05-10 | 2012-05-11 | 90, 94, 109 | 10d | 0d | ENGR; Project Manager | 32h | 1,840 |  |
| 111 | 1.3.2.5 | Approve |  | 1d | 2012-05-14 | 2012-05-14 | 109, 110 | 10d | 0d | Project Manager | 8h | 480 | PCB DESIGN READY |
| 112 | 1.3.2.6 | PCB Fabrication |  | 8d | 2012-05-15 | 2012-05-24 | 111 | 10d | 6d | PCB Fabricator | 64h | 2,560 | PCB PROTOTYPE |
| 113 | 1.3.3 | **Housing** |  | 73d | 2012-03-16 | 2012-06-26 |  | 7d |  |  | 296h | 9,000 |  |
| 114 | 1.3.3.1 | **Industrial Design** |  | 16d | 2012-03-27 | 2012-04-17 |  | 0d |  |  | 128h |  |  |
| 115 | 1.3.3.1.1 | Review & Approval |  | 16d | 2012-03-27 | 2012-04-17 | 18 | 0d |  | CONSULTANT | 128h |  |  |
| 116 | 1.3.3.2 | **Mechanical Design** |  | 12d | 2012-04-18 | 2012-05-03 |  | 0d |  |  | 96h | 4,800 |  |
| 117 | 1.3.3.2.1 | 3D CAD |  | 5d | 2012-04-18 | 2012-04-24 | 115 | 0d |  | Mechanical ENGR | 40h | 2,000 |  |
| 118 | 1.3.3.2.2 | Design Review |  | 1d | 2012-04-25 | 2012-04-25 | 117 | 0d |  | Mechanical ENGR | 8h | 400 |  |
| 119 | 1.3.3.2.3 | DFM |  | 2d | 2012-04-26 | 2012-04-27 | 118 | 0d |  | Mechanical ENGR | 16h | 800 |  |
| 120 | 1.3.3.2.4 | Approve | milestone | 0d | 2012-04-27 | 2012-04-27 | 119 | 0d |  | Mechanical ENGR; Project Manager |  |  |  |
| 121 | 1.3.3.2.5 | Part Drawings |  | 4d | 2012-04-30 | 2012-05-03 | 120 | 0d |  | Mechanical ENGR | 32h | 1,600 | MECH DESIGN |
| 122 | 1.3.3.3 | **Tooling** |  | 68d | 2012-03-16 | 2012-06-19 |  | 33d |  |  | 48h | 2,880 |  |
| 123 | 1.3.3.3.1 | Tooling Design |  | 2d | 2012-04-30 | 2012-05-01 | 120 | 2d | 0d | ODM/CM | 16h | 1,120 |  |
| 124 | 1.3.3.3.2 | Pre-lim tooling (T0) |  | 20d | 2012-05-04 | 2012-05-31 | 121, 123 | 0d |  |  |  |  |  |
| 125 | 1.3.3.3.3 | Final tooling (T1) |  | 13d | 2012-06-01 | 2012-06-19 | 124 | 0d |  |  |  |  | TOOLING COMPLETE |
| 126 | 1.3.3.3.4 | **Capacity Plan** |  | 1d | 2012-05-02 | 2012-05-02 |  | 82d |  |  | 16h | 880 |  |
| 127 | 1.3.3.3.4.1 | Review & Approval |  | 1d | 2012-05-02 | 2012-05-02 | 123 | 82d |  | Product ENGR; Operations | 16h | 880 |  |
| 128 | 1.3.3.3.5 | **Ramp-up Plan** |  | 1d | 2012-03-16 | 2012-03-16 |  | 115d |  |  | 16h | 880 |  |
| 129 | 1.3.3.3.5.1 | Review & Approval |  | 1d | 2012-03-16 | 2012-03-16 | 14 | 115d |  | Product ENGR; Operations | 16h | 880 |  |
| 130 | 1.3.3.4 | Housing Approved |  | 3d | 2012-06-22 | 2012-06-26 | 120, 125 | 0d |  | ENGR | 24h | 1,320 | MP HOUSING DONE |

| ID | WBS | Task | Type | Duration | Start | Finish | Predecessors | Total slack | Free slack | Resources | Work | Cost | Deliverable |
| --- | --- | --- | --- | --- | --- | --- | --- | --- | --- | --- | --- | --- | --- |
| 131 | 1.3.4 | **Packaging** |  | 88d | 2012-02-23 | 2012-06-25 |  | 44d |  |  | 464h | 23,360 |  |
| 132 | 1.3.4.1 | **Dummy** |  | 14d | 2012-05-04 | 2012-05-23 |  | 35d |  |  |  |  |  |
| 133 | 1.3.4.1.1 | Dummy Unit /Evaluate Button Functionality |  | 10d | 2012-05-04 | 2012-05-17 | 121 | 35d | 0d |  |  |  |  |
| 134 | 1.3.4.1.2 | Dummy Review and Approval |  | 4d | 2012-05-18 | 2012-05-23 | 133 | 35d | 0d |  |  |  |  |
| 135 | 1.3.4.2 | **Clamshell** |  | 37d | 2012-05-04 | 2012-06-25 |  | 34d |  |  | 312h | 15,920 |  |
| 136 | 1.3.4.2.1 | Clamshell Design |  | 3d | 2012-05-21 | 2012-05-23 | 65, 120 | 35d | 0d | Packaging ENGR | 24h | 1,200 | CLAMSHELL DESIGN |
| 137 | 1.3.4.2.2 | Clamshell Prototype Tool 20 units |  | 7d | 2012-05-24 | 2012-06-01 | 134, 136 | 35d | 0d | Packaging ENGR | 56h | 2,800 |  |
| 138 | 1.3.4.2.3 | FAI/Review & approval (Shipping included) |  | 4d | 2012-06-06 | 2012-06-11 | 137 | 33d | 0d | Packaging ENGR | 32h | 1,600 |  |
| 139 | 1.3.4.2.4 | Production Tool 20 units |  | 6d | 2012-06-12 | 2012-06-19 | 138 | 33d | 0d | Packaging ENGR | 48h | 2,400 |  |
| 140 | 1.3.4.2.5 | FAI/Review & Approval |  | 4d | 2012-06-20 | 2012-06-25 | 139 | 33d | 0d | Packaging ENGR | 32h | 1,600 | CLAMSHELL APPR'D |
| 141 | 1.3.4.2.6 | **Insert** |  | 15d | 2012-05-04 | 2012-05-24 |  | 56d |  |  | 120h | 6,320 |  |
| 142 | 1.3.4.2.6.1 | Clamshell Insert Design |  | 4d | 2012-05-04 | 2012-05-09 | 65, 120 | 56d | 0d | Packaging ENGR | 32h | 1,600 | INSERT DESIGN |
| 143 | 1.3.4.2.6.2 | Clamshell Insert Production Items |  | 7d | 2012-05-10 | 2012-05-18 | 142 | 56d | 0d | Packaging ENGR | 56h | 2,800 |  |
| 144 | 1.3.4.2.6.3 | FAI Review & Approval |  | 4d | 2012-05-21 | 2012-05-24 | 143 | 56d | 0d | Product MKTG | 32h | 1,920 | INSERT APPR'D |
| 145 | 1.3.4.3 | User Guide | milestone | 0d | 2012-03-12 | 2012-03-12 | 65 | 119d |  | Packaging ENGR |  |  |  |
| 146 | 1.3.4.4 | Insert Design | milestone | 0d | 2012-03-12 | 2012-03-12 | 65 | 119d |  | Packaging ENGR |  |  |  |
| 147 | 1.3.4.5 | **QSG** |  | 59d | 2012-02-23 | 2012-05-15 |  | 73d |  |  | 64h | 3,520 |  |
| 148 | 1.3.4.5.1 | QSG Copy | milestone | 0d | 2012-02-23 | 2012-02-23 |  | 120d | 47d | Product Manager |  |  |  |
| 149 | 1.3.4.5.2 | QSG Design |  | 4d | 2012-04-30 | 2012-05-03 | 65, 120, 148 | 73d | 0d | Packaging ENGR | 32h | 1,600 | QSG DESIGN |
| 150 | 1.3.4.5.3 | QSG Productions Items |  | 4d | 2012-05-04 | 2012-05-09 | 149 | 73d | 0d |  |  |  |  |
| 151 | 1.3.4.5.4 | FAI Review & Approval |  | 4d | 2012-05-10 | 2012-05-15 | 150 | 73d |  | Product Manager | 32h | 1,920 | QSG APPR'D |
| 152 | 1.3.4.6 | Collateral Design | milestone | 0d | 2012-03-12 | 2012-03-12 | 65 | 109d | 0d | Packaging ENGR |  |  |  |
| 153 | 1.3.4.7 | Label Design | milestone | 0d | 2012-03-12 | 2012-03-12 | 65 | 109d | 0d | Packaging ENGR |  |  | LABEL DESIGN |
| 154 | 1.3.4.8 | Retail Box Design | milestone | 0d | 2012-03-12 | 2012-03-12 | 65 | 109d | 0d | Packaging ENGR |  |  | BOX DESIGN |

| ID | WBS | Task | Type | Duration | Start | Finish | Predecessors | Total slack | Free slack | Resources | Work | Cost | Deliverable |
| --- | --- | --- | --- | --- | --- | --- | --- | --- | --- | --- | --- | --- | --- |
| 155 | 1.3.4.9 | **Shipping Corrugate** |  | 27d | 2012-04-27 | 2012-06-05 |  | 58d |  |  | 88h | 3,920 |  |
| 156 | 1.3.4.9.1 | Shipping Corugate Design | milestone | 0d | 2012-04-27 | 2012-04-27 | 65, 120 | 85d |  | Packaging ENGR |  |  |  |
| 157 | 1.3.4.9.2 | Production samples |  | 5d | 2012-05-28 | 2012-06-01 | 137FF | 48d | 0d | Outside vendor | 40h | 1,200 |  |
| 158 | 1.3.4.9.3 | FAI Review & Approval |  | 2d | 2012-06-04 | 2012-06-05 | 157 | 48d | 0d | Packaging ENGR; Project Manager; Product Manager | 48h | 2,720 |  |
| 159 | 1.3.5 | **BOM** |  | 2d | 2012-03-16 | 2012-03-19 |  | 103d |  |  | 32h | 1,840 |  |
| 160 | 1.3.5.1 | Marketing Pre-lim BOM |  | 1d | 2012-03-16 | 2012-03-16 | 14 | 115d |  | Product Manager; Project Manager | 16h | 960 | SKU APPR'D |
| 161 | 1.3.5.2 | Engineering Pre-lim BOM |  | 2d | 2012-03-16 | 2012-03-19 | 14 | 103d | 82d | ENGR | 16h | 880 | BOM APPR'D |
| 162 | 1.3.6 | **Pre-planning** |  | 2d | 2012-02-27 | 2012-02-28 |  | 127d |  |  | 32h | 2,560 |  |
| 163 | 1.3.6.1 | Pre-lim Forecast Frozen |  | 1d | 2012-02-27 | 2012-02-27 | 5 | 127d | 0d | VP of MKTG; Product Manager | 16h | 1,280 |  |
| 164 | 1.3.6.2 | Pre-lim-Forecast in Oracle |  | 1d | 2012-02-28 | 2012-02-28 | 163 | 127d | 15d | VP of MKTG; Product Manager | 16h | 1,280 |  |
| 165 | 1.3.7 | **Engineering Validation Test (EVT)** |  | 10d | 2012-06-01 | 2012-06-14 |  | 4d |  |  | 80h | 4,160 |  |
| 166 | 1.3.7.1 | T0 Mechanical |  | 1d | 2012-06-01 | 2012-06-01 | 124 | 4d | 0d | Product ENGR | 8h | 400 |  |
| 167 | 1.3.7.2 | EVT prototypes 2 units |  | 5d | 2012-06-04 | 2012-06-08 | 112, 166 | 4d | 0d | Product ENGR | 40h | 2,000 |  |
| 168 | 1.3.7.3 | Engineering Validation Testing |  | 3d | 2012-06-11 | 2012-06-13 | 167 | 4d | 0d | ENGR | 24h | 1,320 |  |
| 169 | 1.3.7.4 | Approve |  | 1d | 2012-06-14 | 2012-06-14 | 168 | 4d | 0d | ENGR | 8h | 440 | EVT APPR'D |
| 170 | 1.3.8 | **Design Validation Test (DVT)** |  | 51d | 2012-06-15 | 2012-08-24 |  | 0d |  |  | 448h | 22,920 |  |
| 171 | 1.3.8.1 | Changes from EVT |  | 5d | 2012-06-15 | 2012-06-21 | 169 | 4d |  | ENGR | 40h | 2,200 |  |
| 172 | 1.3.8.2 | T1 Mechanical |  | 1d | 2012-06-27 | 2012-06-27 | 130 | 0d |  | Product ENGR | 8h | 400 |  |
| 173 | 1.3.8.3 | DVT prototypes 10 units |  | 5d | 2012-06-28 | 2012-07-04 | 171, 172 | 0d |  | Product ENGR | 40h | 2,000 |  |
| 174 | 1.3.8.4 | Design Validation Testing |  | 7d | 2012-07-13 | 2012-07-26 | 173 | 11d | 10d | ENGR | 56h | 3,080 | DVT APPR'D |
| 175 | 1.3.8.5 | **PCB Qualification** |  | 37d | 2012-07-05 | 2012-08-24 |  | 0d |  |  | 296h | 14,800 |  |
| 176 | 1.3.8.5.1 | EMI |  | 5d | 2012-07-05 | 2012-07-11 | 173 | 0d |  | Outside Cert Lab | 40h | 2,000 |  |
| 177 | 1.3.8.5.2 | ESD | milestone | 0d | 2012-07-11 | 2012-07-11 | 176 | 1d | 0d | Outside Cert Lab |  |  |  |
| 178 | 1.3.8.5.3 | FCC | milestone | 0d | 2012-07-11 | 2012-07-11 | 177 | 32d |  | Outside Cert Lab |  |  |  |
| 179 | 1.3.8.5.4 | USB IF |  | 10d | 2012-07-27 | 2012-08-09 | 176 | 11d |  | Outside Cert Lab | 80h | 4,000 |  |
| 180 | 1.3.8.5.5 | WHQL |  | 11d | 2012-08-10 | 2012-08-24 | 176 | 0d |  | Outside Cert Lab | 88h | 4,400 |  |
| 181 | 1.3.8.5.6 | Certificate |  | 11d | 2012-07-12 | 2012-07-26 | 177 | 21d |  | Outside Cert Lab | 88h | 4,400 |  |
| 182 | 1.3.8.6 | Approve |  | 1d | 2012-07-12 | 2012-07-12 | 176, 177 | 1d | 0d | ENGR | 8h | 440 | ALL CERTS DONE |

| ID | WBS | Task | Type | Duration | Start | Finish | Predecessors | Remaining | Total slack | Free slack | Resources | Work | Cost | Deliverable |
| --- | --- | --- | --- | --- | --- | --- | --- | --- | --- | --- | --- | --- | --- | --- |
| 183 | 1.3.9 | **Phase 2 gate** |  | 2d | 2012-07-13 | 2012-07-16 |  |  | 27d |  |  | 32h | 2,560 |  |
| 184 | 1.3.9.1 | Review & Approval |  | 2d | 2012-07-13 | 2012-07-16 | 54, 105, 182 |  | 27d | 20d | Project Manager; VP of MKTG | 32h | 2,560 |  |
| 185 | 1.4 | **Phase 3 (Qualification)** |  | 112d | 2012-03-12 A | 2012-08-15 |  | 112d | 7d |  |  | 528h | 31,640 |  |
| 186 | 1.4.1 | **Packaging** |  | 76d | 2012-03-12 A | 2012-06-26 |  | 76d | 43d |  |  | 128h | 8,320 |  |
| 187 | 1.4.1.1 | Die Lines (all components) | milestone | 0d | 2012-03-12 | 2012-03-12 | 65 |  | 105d | 0d | Packaging ENGR |  |  |  |
| 188 | 1.4.1.2 | **Clamshell** |  | 20d | 2012-05-29 A | 2012-06-26 |  | 20d | 43d |  |  |  |  |  |
| 189 | 1.4.1.2.1 | Prototype Sample delivery & approval | milestone | 0d | 2012-06-11 | 2012-06-11 | 138 |  | 54d |  | Packaging ENGR |  |  |  |
| 190 | 1.4.1.2.2 | Production samples (20 units) |  | 1d | 2012-05-29 A | 2012-06-26 | 140 | 1d | 33d | 0d |  |  |  |  |
| 191 | 1.4.1.2.3 | FA Review & Approval | milestone | 0d | 2012-06-26 | 2012-06-26 | 190 |  | 33d | 0d | Product Manager; Project Manager |  |  |  |
| 192 | 1.4.1.3 | **Clamshell Insert** |  | 0d | 2012-05-24 | 2012-05-24 |  |  | 56d |  |  |  |  |  |
| 193 | 1.4.1.3.1 | FA Review & Approval | milestone | 0d | 2012-05-24 | 2012-05-24 | 144 |  | 56d | 23d | Product Manager; Project Manager |  |  | CLAMSHELL FA APPR'D |
| 194 | 1.4.1.4 | **Collateral** |  | 0d | 2012-03-12 | 2012-03-12 |  |  | 109d |  |  |  |  |  |
| 195 | 1.4.1.4.1 | FA Review & Approval | milestone | 0d | 2012-03-12 | 2012-03-12 | 152 |  | 109d | 76d | Product Manager; Project Manager |  |  | QSG FA APPR'D |
| 196 | 1.4.1.5 | **Labels** |  | 0d | 2012-03-12 | 2012-03-12 |  |  | 109d |  |  |  |  |  |
| 197 | 1.4.1.5.1 | FA Review & Approval | milestone | 0d | 2012-03-12 | 2012-03-12 | 153 |  | 109d | 76d | Product Manager; Project Manager |  |  | LABEL FA APPR'D |
| 198 | 1.4.1.6 | **Retail Box Artwork** |  | 0d | 2012-03-12 | 2012-03-12 |  |  | 109d |  |  |  |  |  |
| 199 | 1.4.1.6.1 | FA Review & Approval | milestone | 0d | 2012-03-12 | 2012-03-12 | 154 |  | 109d | 0d | Product Manager; Project Manager |  |  | PRODUCT BOX APPR'D |
| 200 | 1.4.1.7 | **FG Box** |  | 0d | 2012-03-12 | 2012-03-12 |  |  | 109d |  |  |  |  |  |
| 201 | 1.4.1.7.1 | FA Review & Approval | milestone | 0d | 2012-03-12 | 2012-03-12 | 199 |  | 109d | 76d | Product Manager; Project Manager |  |  | FG BOX FA APPR'D |
| 202 | 1.4.1.8 | **Shipping Corrugate** |  | 0d | 2012-06-05 | 2012-06-05 |  |  | 48d |  |  |  |  |  |
| 203 | 1.4.1.8.1 | FA Review & Approval | milestone | 0d | 2012-06-05 | 2012-06-05 | 158 |  | 48d | 15d | Product Manager; Project Manager |  |  | CORRUGATE FA APPR'D |
| 204 | 1.4.1.9 | **Package Qualification** |  | 14d | 2012-03-13 | 2012-03-30 |  |  | 105d |  |  | 128h | 8,320 |  |
| 205 | 1.4.1.9.1 | **Packaging Test** |  | 12.5d | 2012-03-13 | 2012-03-29 |  |  | 105d | 0d |  | 104h | 7,120 |  |
| 206 | 1.4.1.9.1.1 | Testing |  | 12d | 2012-03-13 | 2012-03-28 | 187 |  | 105d | 0d | ODM/CM | 96h | 6,720 |  |
| 207 | 1.4.1.9.1.2 | Report Review & Approval |  | 0.5d | 2012-03-29 | 2012-03-29 | 206 |  | 105d |  | Product ENGR; Packaging ENGR | 8h | 400 |  |

| ID | WBS | Task | Type | Duration | Start | Finish | Predecessors | Total slack | Free slack | Resources | Work | Cost | Deliverable |
| --- | --- | --- | --- | --- | --- | --- | --- | --- | --- | --- | --- | --- | --- |
| 208 | 1.4.1.9.2 | **Packaging Test Sample** |  | 1.5d | 2012-03-29 | 2012-03-30 |  | 105d |  |  | 24h | 1,200 |  |
| 209 | 1.4.1.9.2.1 | Review & Approval |  | 1.5d | 2012-03-29 | 2012-03-30 | 205 | 105d |  | Product ENGR; Packaging ENGR | 24h | 1,200 |  |
| 210 | 1.4.2 | All packaging Items approved | milestone | 0d | 2012-06-26 | 2012-06-26 | 187, 191, 193, 195, 197, 199, 201, 203 | 33d | 32d | Product Manager; Project Manager |  |  | ALL PACK APPR'D |
| 211 | 1.4.3 | **BOM** |  | 4d | 2012-05-15 | 2012-05-18 |  | 61d |  |  | 32h | 1,840 |  |
| 212 | 1.4.3.1 | Engineering PVT |  | 2d | 2012-05-15 | 2012-05-16 | 111 | 61d | 0d | ENGR | 16h | 880 | PVT RELEASE NOTICE |
| 213 | 1.4.3.2 | Marketing PVT |  | 2d | 2012-05-17 | 2012-05-18 | 212 | 61d | 41d | Product Manager | 16h | 960 |  |
| 214 | 1.4.4 | **Production Validation Test (PVT)** |  | 63d | 2012-05-15 | 2012-08-09 |  | 1d |  |  | 216h | 11,960 |  |
| 215 | 1.4.4.1 | **PVT Build** |  | 58d | 2012-05-15 | 2012-08-02 |  | 1d |  |  | 88h | 5,280 |  |
| 216 | 1.4.4.1.1 | Material PO |  | 1d | 2012-05-15 | 2012-05-15 | 111, 123 | 43d | 42d | Planning | 8h | 480 | PVT PO PLACED |
| 217 | 1.4.4.1.2 | Build 500 functional units |  | 10d | 2012-07-18 | 2012-08-02 | 182, 216 | 1d | 0d | Operations | 80h | 4,800 | PVT PO PLACED |
| 218 | 1.4.4.2 | **Samples** |  | 4d | 2012-08-03 | 2012-08-08 |  | 1d |  |  | 32h | 1,600 |  |
| 219 | 1.4.4.2.1 | Marketing Sample Delivery |  | 4d | 2012-08-03 | 2012-08-08 | 217 | 1d | 0d | Product ENGR | 32h | 1,600 |  |
| 220 | 1.4.4.2.2 | Preproduction Sample Delivery | milestone | 0d | 2012-08-08 | 2012-08-08 | 219 | 1d | 0d | Product ENGR |  |  |  |
| 221 | 1.4.4.3 | **FAI (unit without Mrktg Packaging)** |  | 1d | 2012-08-09 | 2012-08-09 |  | 1d |  |  | 16h | 960 |  |
| 222 | 1.4.4.3.1 | Review & Approve |  | 1d | 2012-08-09 | 2012-08-09 | 220 | 1d | 0d | Product Manager; Project Manager | 16h | 960 |  |
| 223 | 1.4.4.4 | **PVT Testing** |  | 17d | 2012-07-05 | 2012-07-27 |  | 10d |  |  | 80h | 4,120 |  |
| 224 | 1.4.4.4.1 | Mechanical Test |  | 7d | 2012-07-05 | 2012-07-13 | 173 | 10d | 0d | Product ENGR | 56h | 2,800 |  |
| 225 | 1.4.4.4.2 | Applications Compatibility Test | milestone | 0d | 2012-07-13 | 2012-07-13 | 224 | 10d | 0d | Product ENGR |  |  |  |
| 226 | 1.4.4.4.3 | Certification / Compliance Qual | milestone | 0d | 2012-07-13 | 2012-07-13 | 225 | 10d | 0d | Product ENGR |  |  |  |
| 227 | 1.4.4.4.4 | Product Reliability Qualification | milestone | 0d | 2012-07-13 | 2012-07-13 | 226 | 10d | 0d | Product ENGR |  |  |  |
| 228 | 1.4.4.4.5 | Yeild Analysis | milestone | 0d | 2012-07-13 | 2012-07-13 | 227 | 10d | 0d | Operations |  |  |  |
| 229 | 1.4.4.4.6 | PVT Testing approved |  | 3d | 2012-07-17 | 2012-07-27 | 225, 226, 227, 228 | 10d | 0d | ENGR | 24h | 1,320 | PVT APPR'D |
| 230 | 1.4.5 | **FAI - Production Samples FG** |  | 1d | 2012-08-10 | 2012-08-10 |  | 1d |  |  | 8h | 480 |  |
| 231 | 1.4.5.1 | FA Review & Approval |  | 1d | 2012-08-10 | 2012-08-10 | 169, 174, 182, 210, 222, 229 | 1d | 0d | Product Manager | 8h | 480 |  |

| ID | WBS | Task | Type | Duration | Start | Finish | Predecessors | Total slack | Free slack | Resources | Work | Cost | Deliverable |
| --- | --- | --- | --- | --- | --- | --- | --- | --- | --- | --- | --- | --- | --- |
| 232 | 1.4.6 | **CM/ODM Readiness** |  | 98d | 2012-03-21 | 2012-08-03 |  | 15d |  |  | 96h | 5,560 |  |
| 233 | 1.4.6.1 | Final Forecast |  | 1d | 2012-03-21 | 2012-03-21 | 90, 164 | 112d |  | Operations | 8h | 480 |  |
| 234 | 1.4.6.2 | Hand Off Packet |  | 5d | 2012-07-30 | 2012-08-03 | 217SF-1d | 15d |  | ENGR | 40h | 2,200 |  |
| 235 | 1.4.6.3 | Material in Place for ISO (Components - PCB, Memory, Controllers, Housing) |  | 1d | 2012-07-12 | 2012-07-12 | 161, 177 | 21d | 0d | Operations | 8h | 480 | BOM COMPONENTS IN |
| 236 | 1.4.6.4 | PO for ISO Builds |  | 1d | 2012-07-13 | 2012-07-13 | 97, 108, 235 | 21d | 0d | Operations | 8h | 480 | MP PO PLACED |
| 237 | 1.4.6.5 | W/O |  | 1d | 2012-07-16 | 2012-07-16 | 236 | 24d | 0d | Operations | 8h | 480 |  |
| 238 | 1.4.6.6 | ISO Builds |  | 1d | 2012-07-17 | 2012-07-17 | 213, 237 | 24d | 8d | Operations | 8h | 480 | MP BUILD COMPLETE |
| 239 | 1.4.6.7 | Ramp-up |  | 1d | 2012-07-30 | 2012-07-30 | 94, 229, 238 | 16d | 0d | Operations | 8h | 480 |  |
| 240 | 1.4.6.8 | Work Sheet Approved |  | 1d | 2012-07-31 | 2012-07-31 | 239 | 16d | 9d | Operations | 8h | 480 |  |
| 241 | 1.4.7 | **BOM** |  | 1d | 2012-08-13 | 2012-08-13 |  | 7d |  |  | 16h | 920 |  |
| 242 | 1.4.7.1 | Release Notes for Engineering BOM and Marketing BOM |  | 1d | 2012-08-13 | 2012-08-13 | 229, 231 | 7d | 0d | ENGR; Product Manager | 16h | 920 |  |
| 243 | 1.4.8 | **Phase 3 gate** |  | 2d | 2012-08-14 | 2012-08-15 |  | 7d |  |  | 32h | 2,560 |  |
| 244 | 1.4.8.1 | Review & Approve |  | 2d | 2012-08-14 | 2012-08-15 | 184, 231, 240, 242 | 7d |  | Project Manager; VP of MKTG | 32h | 2,560 |  |
| 245 | 1.5 | **Phase 4 (Production)** |  | 9d | 2012-08-10 | 2012-08-23 |  | 1d |  |  | 72h | 4,320 |  |
| 246 | 1.5.1 | FG Launch Buiild | milestone | 0d | 2012-08-10 | 2012-08-10 | 213, 229, 231, 235, 236 | 1d | 0d | Operations; ENGR |  |  |  |
| 247 | 1.5.2 | Taiwan |  | 3d | 2012-08-13 | 2012-08-15 | 246 | 1d | 0d | Operations | 24h | 1,440 | TWN FG |
| 248 | 1.5.3 | NA |  | 3d | 2012-08-21 | 2012-08-23 | 247 | 1d |  | Operations | 24h | 1,440 | US FG |
| 249 | 1.5.4 | EU |  | 3d | 2012-08-16 | 2012-08-20 | 247 | 4d | 0d | Operations | 24h | 1,440 | EU FG |
| 250 | 1.5.5 | Mass-Production | milestone | 0d | 2012-08-20 | 2012-08-20 | 249 | 4d |  | Operations |  |  | PROJECT COMPLETE |
