# USB Flash Drive_03152012_prefinal2

Schedule from MS Project, 2012-02-23 to 2012-08-30, costs in $, A marks actual dates.

## Calendars

- Standard: Mon-Fri 08:00-12:00, 13:00-17:00; Sat-Sun off.

## Resources

| Resource | Group | Rate |
| --- | --- | --- |
| Product Manager | Employee | 60 |
| VP of MKTG | Contract | 100 |
| Project Manager | Employee | 60 |
| ENGR | Employee | 55 |
| Operations | Employee | 60 |
| Mechanical ENGR | Employee | 50 |
| Procurement | Employee | 60 |
| CEO | Contract | 200 |
| Packaging ENGR | Employee | 50 |
| Product ENGR | Employee | 50 |
| PCB Fabricator | Outside services | 40 |
| ODM/CM | Outside services | 70 |
| Product MKTG | Employee | 60 |
| Outside vendor | Outside services | 30 |
| Outside Cert Lab | Outside services | 50 |
| Planning | Employee | 60 |
| CONSULTANT | Consulting | 80 |
| Administrative | Administrative | 40 |
| NAND supplier | Materials | 5 |
| PCB supplier | Materials | 2 |
| Passives supplier | Materials | 0.05 |
| CONtroller supplier | Materials | 5 |
| Housing supplier | Materials | 6 |
| Other supplier | Materials | 2 |

## Schedule

| ID | WBS | Task | Type | Duration | Start | Finish | Predecessors | Complete | Remaining | Total slack | Resources | Work | Actual work | Cost | Actual cost | Deliverable |
| --- | --- | --- | --- | --- | --- | --- | --- | --- | --- | --- | --- | --- | --- | --- | --- | --- |
| 1 | 1 | **USB Flash Drive** |  | 136d | 2012-02-23 A | 2012-08-30 |  | 4% | 130.29d | 0d |  | 3216h | 216h | 789,840 | 13,600 |  |
| 2 | 1.1 | **Phase 0 (Business Case)** |  | 5d | 2012-02-23 A | 2012-02-29 A |  | 100% |  |  |  | 32h | 32h | 2,240 | 2,240 |  |
| 3 | 1.1.1 | MRD |  | 1d | 2012-02-23 A | 2012-02-23 A |  | 100% |  |  | Product Manager | 8h | 8h | 480 | 480 |  |
| 4 | 1.1.2 | Marketing Review |  | 1d | 2012-02-24 A | 2012-02-24 A | 3 | 100% |  |  | Product Manager | 8h | 8h | 480 | 480 |  |
| 5 | 1.1.3 | Marketing Approval | milestone | 0d | 2012-02-24 A | 2012-02-24 A | 4 | 100% |  |  | Product Manager |  |  |  |  |  |
| 6 | 1.1.4 | **Phase 0 Gate** |  | 1d | 2012-02-29 A | 2012-02-29 A |  | 100% |  |  |  | 16h | 16h | 1,280 | 1,280 |  |
| 7 | 1.1.4.1 | Review & approve |  | 1d | 2012-02-29 A | 2012-02-29 A | 5 | 100% |  |  | Product Manager; VP of MKTG | 16h | 16h | 1,280 | 1,280 | MRD |
| 8 | 1.2 | **Phase 1 (Planning)** |  | 74d | 2012-03-01 A | 2012-06-12 |  | 28% | 53.09d | 53d |  | 480h | 152h | 31,680 | 8,800 |  |
| 9 | 1.2.1 | Internal Kick Off Meeting |  | 1d | 2012-03-01 A | 2012-03-01 A | 7 | 100% |  |  | Project Manager | 8h | 8h | 480 | 480 |  |
| 10 | 1.2.2 | **Requirements** |  | 65d | 2012-03-02 A | 2012-05-31 |  | 40% | 39d | 0d |  | 312h | 144h | 18,200 | 8,320 |  |
| 11 | 1.2.2.1 | **PRD** |  | 7d | 2012-03-07 A | 2012-03-15 A |  | 100% |  |  |  | 80h | 80h | 4,600 | 4,600 |  |
| 12 | 1.2.2.1.1 | Generate PRD |  | 5d | 2012-03-07 A | 2012-03-13 A | 9 | 100% |  |  | Project Manager; ENGR | 48h | 48h | 2,760 | 2,760 |  |
| 13 | 1.2.2.1.2 | Internal review |  | 2d | 2012-03-14 A | 2012-03-15 A | 12 | 100% |  |  | ENGR; Project Manager | 32h | 32h | 1,840 | 1,840 |  |
| 14 | 1.2.2.1.3 | Internal approval | milestone | 0d | 2012-03-15 A | 2012-03-15 A | 13 | 100% |  |  | Project Manager; VP of MKTG |  |  |  |  | PRD |
| 15 | 1.2.2.2 | **Industrial Design** |  | 17d | 2012-03-02 | 2012-03-26 |  |  |  | 0d |  | 40h |  | 2,320 |  |  |
| 16 | 1.2.2.2.1 | Contractor Selection |  | 2d | 2012-03-02 | 2012-03-22 | 9 |  |  | 0d | Operations; Project Manager | 16h |  | 960 |  |  |
| 17 | 1.2.2.2.2 | Initial Industrial Design |  | 1d | 2012-03-23 | 2012-03-23 | 16 |  |  | 0d | Mechanical ENGR | 8h |  | 400 |  |  |
| 18 | 1.2.2.2.3 | Review |  | 1d | 2012-03-26 | 2012-03-26 | 17 |  |  | 0d | Project Manager; Operations | 16h |  | 960 |  |  |
| 19 | 1.2.2.3 | **Outsourcing - Suppliers/Partners Selection** |  | 65d | 2012-03-02 A | 2012-05-31 |  | 26% | 47.89d | 0d |  | 192h | 64h | 11,280 | 3,720 |  |
| 20 | 1.2.2.3.1 | **RFQ process** |  | 65d | 2012-03-02 A | 2012-05-31 |  | 26% | 47.89d | 0d |  | 192h | 64h | 11,280 | 3,720 |  |
| 21 | 1.2.2.3.1.1 | Generate List of Potential Partners |  | 1d | 2012-03-02 A | 2012-03-02 A | 9 | 100% |  |  | Procurement | 8h | 8h | 480 | 480 |  |
| 22 | 1.2.2.3.1.2 | Suppliers/Partners Review |  | 4d | 2012-03-05 | 2012-03-27 | 21 |  |  | 0d | Project Manager; Procurement | 32h |  | 1,920 |  |  |
| 23 | 1.2.2.3.1.3 | Issue RFQs including PRD |  | 1d | 2012-03-28 | 2012-03-28 | 14, 22 |  |  | 0d | Procurement | 8h |  | 480 |  | RFQ COMPLETE |
| 24 | 1.2.2.3.1.4 | **ODM Quote completed** |  | 34d | 2012-03-29 | 2012-05-15 |  |  |  | 0d |  | 48h |  | 2,840 |  |  |
| 25 | 1.2.2.3.1.4.1 | Review Financial Terms |  | 1d | 2012-03-29 | 2012-03-29 | 23 |  |  | 32d | Procurement | 8h |  | 480 |  |  |
| 26 | 1.2.2.3.1.4.2 | Review Technical Capabilities |  | 2d | 2012-03-30 | 2012-05-14 | 23 |  |  | 0d | ENGR; Project Manager | 16h |  | 920 |  |  |
| 27 | 1.2.2.3.1.4.3 | Review Production Capabilities |  | 1d | 2012-03-29 | 2012-03-29 | 23 |  |  | 32d | Project Manager; Operations | 16h |  | 960 |  |  |
| 28 | 1.2.2.3.1.4.4 | ODM/CM Selection |  | 1d | 2012-05-15 | 2012-05-15 | 25, 26, 27 |  |  | 0d | Procurement | 8h |  | 480 |  | ODM/CM AWARD |
| 29 | 1.2.2.3.1.5 | Supplier Kick off Meeting |  | 2d | 2012-05-16 | 2012-05-29 | 14, 18, 28 |  |  | 0d | ENGR; Project Manager | 16h |  | 920 |  |  |

| ID | WBS | Task | Type | Duration | Start | Finish | Predecessors | Complete | Total slack | Free slack | Resources | Work | Actual work | Cost | Actual cost | Deliverable |
| --- | --- | --- | --- | --- | --- | --- | --- | --- | --- | --- | --- | --- | --- | --- | --- | --- |
| 30 | 1.2.2.3.1.6 | **Contractor Quote Completed** |  | 4d | 2012-03-02 A | 2012-03-07 A |  | 100% |  |  |  | 56h | 56h | 3,240 | 3,240 |  |
| 31 | 1.2.2.3.1.6.1 | **SOW** |  | 3d | 2012-03-02 A | 2012-03-06 A |  | 100% |  |  |  | 48h | 48h | 2,760 | 2,760 |  |
| 32 | 1.2.2.3.1.6.1.1 | Generate SOW |  | 3d | 2012-03-02 A | 2012-03-06 A | 9 | 100% |  |  | ENGR; Project Manager | 48h | 48h | 2,760 | 2,760 |  |
| 33 | 1.2.2.3.1.6.1.2 | Approved | milestone | 0d | 2012-03-06 A | 2012-03-06 A | 32 | 100% |  |  | Project Manager |  |  |  |  |  |
| 34 | 1.2.2.3.1.6.2 | Review |  | 1d | 2012-03-07 A | 2012-03-07 A | 33 | 100% |  |  | Project Manager | 8h | 8h | 480 | 480 |  |
| 35 | 1.2.2.3.1.6.3 | Contractor Selection | milestone | 0d | 2012-03-07 A | 2012-03-07 A | 34 | 100% |  |  | Project Manager; Procurement |  |  |  |  |  |
| 36 | 1.2.2.3.1.7 | **Mechanical Manufacturing (Shell/Housing)** |  | 2d | 2012-05-30 | 2012-05-31 |  |  | 0d |  |  | 24h |  | 1,400 |  |  |
| 37 | 1.2.2.3.1.7.1 | Review |  | 1d | 2012-05-30 | 2012-05-30 | 14, 29 |  | 0d |  | ENGR | 8h |  | 440 |  |  |
| 38 | 1.2.2.3.1.7.2 | Contractor Selection | milestone | 0d | 2012-05-30 | 2012-05-30 | 37 |  | 0d |  | Operations; Project Manager |  |  |  |  |  |
| 39 | 1.2.2.3.1.7.3 | Kick off Meeting |  | 1d | 2012-05-31 | 2012-05-31 | 38 |  | 0d |  | Project Manager; Operations | 16h |  | 960 |  |  |
| 40 | 1.2.3 | **Schedule** |  | 58d | 2012-03-19 | 2012-06-06 |  |  | 0d |  |  | 56h |  | 4,000 |  |  |
| 41 | 1.2.3.1 | Set-up |  | 3d | 2012-03-19 | 2012-03-28 | 14 |  | 46d |  | Project Manager | 24h |  | 1,440 |  |  |
| 42 | 1.2.3.2 | Review |  | 3d | 2012-06-01 | 2012-06-06 | 29, 39, 41 |  | 0d |  | VP of MKTG; Project Manager | 32h |  | 2,560 |  |  |
| 43 | 1.2.3.3 | Approval | milestone | 0d | 2012-06-06 | 2012-06-06 | 42 |  | 0d |  | VP of MKTG |  |  |  |  | SCHEDULE |
| 44 | 1.2.4 | **BOMs/Routings** |  | 8d | 2012-05-17 | 2012-05-28 |  |  | 60d | 0d |  | 24h |  | 1,320 |  |  |
| 45 | 1.2.4.1 | Engineering PN Generation |  | 1d | 2012-05-18 | 2012-05-18 | 14 |  | 66d |  | ENGR | 8h |  | 440 |  |  |
| 46 | 1.2.4.2 | Marketing BOM (SKU) Initial Status |  | 1d | 2012-05-28 | 2012-05-28 | 14 |  | 60d |  | ENGR | 8h |  | 440 |  | SKU CREATED |
| 47 | 1.2.4.3 | Manufacturing BOM (Technical) Initial Status |  | 1d | 2012-05-17 | 2012-05-17 | 14 |  | 67d | 15d | ENGR | 8h |  | 440 |  |  |
| 48 | 1.2.5 | **Financial Model** |  | 72d | 2012-03-01 | 2012-06-08 |  |  | 53d |  |  | 32h |  | 1,920 |  |  |
| 49 | 1.2.5.1 | Product Development Budget |  | 1d | 2012-06-07 | 2012-06-07 | 28, 39, 43 |  | 53d | 0d | Project Manager | 8h |  | 480 |  |  |
| 50 | 1.2.5.2 | Product Cost |  | 1d | 2012-05-29 | 2012-05-29 | 28, 44 |  | 60d | 7d | Procurement | 8h |  | 480 |  |  |
| 51 | 1.2.5.3 | Marketing Plan |  | 1d | 2012-03-01 | 2012-03-01 | 5 |  | 123d | 70d | Product Manager | 8h |  | 480 |  |  |
| 52 | 1.2.5.4 | ROI/Revenue Projection |  | 1d | 2012-06-08 | 2012-06-08 | 47, 49, 50, 51 |  | 53d | 0d | Product Manager | 8h |  | 480 |  |  |
| 53 | 1.2.6 | **Phase 1 Gate** |  | 2d | 2012-06-11 | 2012-06-12 |  |  | 53d |  |  | 48h |  | 5,760 |  |  |
| 54 | 1.2.6.1 | Review & Approval |  | 2d | 2012-06-11 | 2012-06-12 | 14, 43, 52 |  | 53d | 26d | CEO; VP of MKTG; Project Manager | 48h |  | 5,760 |  |  |

| ID | WBS | Task | Duration | Start | Finish | Predecessors | Complete | Remaining | Total slack | Free slack | Resources | Work | Actual work | Cost | Actual cost | Deliverable |
| --- | --- | --- | --- | --- | --- | --- | --- | --- | --- | --- | --- | --- | --- | --- | --- | --- |
| 55 | 1.3 | **Phase 2 (Development)** | 136d | 2012-02-23 A | 2012-08-30 |  | 1% | 135.09d | 0d |  |  | 2104h | 32h | 113,960 | 2,560 |  |
| 56 | 1.3.1 | **Documentation** | 73d | 2012-03-02 | 2012-06-12 |  |  |  | 14d |  |  | 352h |  | 17,920 |  |  |
| 57 | 1.3.1.1 | **Final Product spec to suppliers / Vendors** | 3d | 2012-03-22 | 2012-03-26 |  |  |  | 0d |  |  | 24h |  | 1,200 |  |  |
| 58 | 1.3.1.1.1 | Develop Spec | 1d | 2012-03-22 | 2012-03-22 | 14 |  |  | 0d |  | ENGR | 8h |  | 440 |  |  |
| 59 | 1.3.1.1.2 | Prepare document | 1d | 2012-03-23 | 2012-03-23 | 58 |  |  | 0d |  | Administrative | 8h |  | 320 |  |  |
| 60 | 1.3.1.1.3 | Review & Approve | 1d | 2012-03-26 | 2012-03-26 | 59 |  |  | 0d |  | ENGR | 8h |  | 440 |  | SPECIFICATION |
| 61 | 1.3.1.2 | **Packaging Plan** | 14d | 2012-03-02 | 2012-03-21 |  |  |  | 64d |  |  | 56h |  | 2,880 |  |  |
| 62 | 1.3.1.2.1 | Define requirements | 1d | 2012-03-02 | 2012-03-02 | 9 |  |  | 65d | 0d | Product Manager | 8h |  | 480 |  |  |
| 63 | 1.3.1.2.2 | Prepare document | 1d | 2012-03-05 | 2012-03-05 | 62 |  |  | 65d | 0d | Administrative | 8h |  | 320 |  |  |
| 64 | 1.3.1.2.3 | Publish Plan | 4d | 2012-03-06 | 2012-03-09 | 63 |  |  | 65d | 0d | Packaging ENGR | 32h |  | 1,600 |  |  |
| 65 | 1.3.1.2.4 | Review & Approved | 1d | 2012-03-21 | 2012-03-21 | 64 |  |  | 64d | 0d | Project Manager | 8h |  | 480 |  | PACK BRIEF |
| 66 | 1.3.1.3 | **Product Qual Plan** | 49d | 2012-03-16 | 2012-05-23 |  |  |  | 66d |  |  | 96h |  | 4,840 |  |  |
| 67 | 1.3.1.3.1 | **Compatibility Test Plan** | 6d | 2012-03-16 | 2012-03-23 |  |  |  | 109d |  |  | 32h |  | 1,640 |  |  |
| 68 | 1.3.1.3.1.1 | Prepare document | 1d | 2012-03-16 | 2012-03-16 | 14 |  |  | 110d | 0d | Administrative | 8h |  | 320 |  |  |
| 69 | 1.3.1.3.1.2 | Publish Plan | 1d | 2012-03-20 | 2012-03-20 | 68 |  |  | 109d | 0d | ENGR | 8h |  | 440 |  |  |
| 70 | 1.3.1.3.1.3 | Review & Approval | 2d | 2012-03-21 | 2012-03-23 | 69 |  |  | 109d | 43d | ENGR | 16h |  | 880 |  | COMPATIBILITY PLAN |
| 71 | 1.3.1.3.2 | **Reliability Plan** | 42d | 2012-03-27 | 2012-05-23 |  |  |  | 66d |  |  | 32h |  | 1,600 |  |  |
| 72 | 1.3.1.3.2.1 | Prepare document | 1d | 2012-03-27 | 2012-03-27 | 14 |  |  | 66d | 0d | Administrative | 8h |  | 320 |  |  |
| 73 | 1.3.1.3.2.2 | Publish Plan | 1d | 2012-05-22 | 2012-05-22 | 72 |  |  | 66d | 0d | ENGR | 8h |  | 440 |  |  |
| 74 | 1.3.1.3.2.3 | Review & Approval | 1d | 2012-05-23 | 2012-05-23 | 73 |  |  | 66d | 0d | Product ENGR; ENGR | 16h |  | 840 |  | RELIABILITY PLAN |
| 75 | 1.3.1.3.3 | **Compliance/Certification Plan** | 41d | 2012-03-26 | 2012-05-21 |  |  |  | 68d |  |  | 32h |  | 1,600 |  |  |
| 76 | 1.3.1.3.3.1 | Prepare document | 1d | 2012-03-26 | 2012-03-26 | 14 |  |  | 68d | 0d | Administrative | 8h |  | 320 |  |  |
| 77 | 1.3.1.3.3.2 | Publish Plan | 1d | 2012-05-15 | 2012-05-15 | 76 |  |  | 68d | 0d | ENGR | 8h |  | 440 |  |  |
| 78 | 1.3.1.3.3.3 | Review & Approval | 2d | 2012-05-17 | 2012-05-21 | 77 |  |  | 68d | 2d | ENGR; Product ENGR | 16h |  | 840 |  | COMPLIANCE PLAN |

| ID | WBS | Task | Type | Duration | Start | Finish | Predecessors | Total slack | Free slack | Resources | Work | Cost | Deliverable |
| --- | --- | --- | --- | --- | --- | --- | --- | --- | --- | --- | --- | --- | --- |
| 79 | 1.3.1.4 | **Packaging Qual Plan** |  | 8d | 2012-03-22 | 2012-04-02 |  | 103d |  |  | 40h | 2,000 |  |
| 80 | 1.3.1.4.1 | Prepare document |  | 1d | 2012-03-22 | 2012-03-22 | 14 | 103d | 0d | Administrative | 8h | 320 |  |
| 81 | 1.3.1.4.2 | Publish Plan |  | 3d | 2012-03-23 | 2012-03-27 | 80 | 103d | 0d | Packaging ENGR | 24h | 1,200 |  |
| 82 | 1.3.1.4.3 | Review & Approval |  | 1d | 2012-04-02 | 2012-04-02 | 81 | 103d | 37d | Project Manager | 8h | 480 | PACK QUAL PLAN |
| 83 | 1.3.1.5 | **QA Plan (IQC, OQC, OQRM, etc)** |  | 9d | 2012-03-21 | 2012-04-02 |  | 103d |  |  | 24h | 1,120 |  |
| 84 | 1.3.1.5.1 | Prepare document |  | 1d | 2012-03-21 | 2012-03-21 | 14 | 103d | 0d | Administrative | 8h | 320 |  |
| 85 | 1.3.1.5.2 | Publish Plan |  | 1d | 2012-03-23 | 2012-03-23 | 84 | 103d | 0d | Product ENGR | 8h | 400 |  |
| 86 | 1.3.1.5.3 | Review & Approval |  | 1d | 2012-04-02 | 2012-04-02 | 85 | 103d | 37d | Product ENGR | 8h | 400 | QA PLAN |
| 87 | 1.3.1.6 | **Production Plan** |  | 3d | 2012-03-20 | 2012-03-22 |  | 35d |  |  | 24h | 1,280 |  |
| 88 | 1.3.1.6.1 | Prepare document |  | 1d | 2012-03-20 | 2012-03-20 | 14 | 35d | 0d | Administrative | 8h | 320 |  |
| 89 | 1.3.1.6.2 | Publish Plan |  | 1d | 2012-03-21 | 2012-03-21 | 88 | 35d | 0d | Operations | 8h | 480 |  |
| 90 | 1.3.1.6.3 | Review & Approval |  | 1d | 2012-03-22 | 2012-03-22 | 89 | 35d | 0d | Operations | 8h | 480 | PRODUCTION PLAN |
| 91 | 1.3.1.7 | **Production Test Plan** |  | 6d | 2012-03-19 | 2012-03-26 |  | 33d |  |  | 24h | 1,120 |  |
| 92 | 1.3.1.7.1 | Prepare document |  | 1d | 2012-03-19 | 2012-03-19 | 14 | 34d | 0d | Administrative | 8h | 320 |  |
| 93 | 1.3.1.7.2 | Publish Plan |  | 1d | 2012-03-22 | 2012-03-22 | 92 | 33d | 1d | Product ENGR | 8h | 400 |  |
| 94 | 1.3.1.7.3 | Review & Approval |  | 1d | 2012-03-26 | 2012-03-26 | 93 | 33d | 0d | Product ENGR | 8h | 400 | PRODUCTION TEST |
| 95 | 1.3.1.8 | **Product Test** |  | 56d | 2012-03-27 | 2012-06-12 |  | 57d |  |  | 56h | 3,080 |  |
| 96 | 1.3.1.8.1 | Product Test Specifications |  | 1d | 2012-06-01 | 2012-06-01 | 60 | 47d | 0d | ENGR | 8h | 440 |  |
| 97 | 1.3.1.8.2 | Test Equipment |  | 2d | 2012-06-04 | 2012-06-12 | 90, 96 | 47d | 26d | Product ENGR; Operations | 16h | 880 |  |
| 98 | 1.3.1.8.3 | **Pre-lim Process** |  | 1d | 2012-03-28 | 2012-03-28 |  | 111d |  |  | 16h | 880 |  |
| 99 | 1.3.1.8.3.1 | Publish Plan |  | 1d | 2012-03-28 | 2012-03-28 | 94 | 111d | 0d | Product ENGR; Operations | 16h | 880 |  |
| 100 | 1.3.1.8.3.2 | Review & Approval | milestone | 0d | 2012-03-28 | 2012-03-28 | 99 | 111d |  | Product ENGR |  |  |  |
| 101 | 1.3.1.8.4 | **Pre-lim Program** |  | 1d | 2012-03-27 | 2012-03-27 |  | 112d |  |  | 16h | 880 |  |
| 102 | 1.3.1.8.4.1 | Publish Plan |  | 1d | 2012-03-27 | 2012-03-27 | 94 | 112d | 0d | Product ENGR; Operations | 16h | 880 |  |
| 103 | 1.3.1.8.4.2 | Review & Approval | milestone | 0d | 2012-03-27 | 2012-03-27 | 102 | 112d |  | Product ENGR |  |  |  |
| 104 | 1.3.1.9 | All qual plans prepared | milestone | 0d | 2012-03-27 | 2012-03-27 | 59, 63, 68, 72, 76, 80, 84, 88, 92 | 112d |  | Administrative |  |  |  |
| 105 | 1.3.1.10 | All Qual Plans Approved |  | 1d | 2012-05-24 | 2012-05-24 | 60, 65, 70, 74, 78, 82, 86, 90, 94 | 66d | 39d | Product ENGR | 8h | 400 |  |

| ID | WBS | Task | Type | Duration | Start | Finish | Predecessors | Total slack | Free slack | Resources | Work | Cost | Deliverable |
| --- | --- | --- | --- | --- | --- | --- | --- | --- | --- | --- | --- | --- | --- |
| 106 | 1.3.2 | **PCB** |  | 53d | 2012-03-27 | 2012-06-07 |  | 0d |  |  | 368h | 19,400 |  |
| 107 | 1.3.2.1 | Schematic Design |  | 8d | 2012-03-27 | 2012-04-05 | 60 | 0d |  | ENGR | 64h | 3,520 |  |
| 108 | 1.3.2.2 | PCB Layout |  | 22d | 2012-04-06 | 2012-05-07 | 107 | 0d |  | ENGR | 176h | 9,680 |  |
| 109 | 1.3.2.3 | Design Review |  | 3d | 2012-05-08 | 2012-05-10 | 108 | 0d |  | ENGR | 24h | 1,320 |  |
| 110 | 1.3.2.4 | Design For Manufacturability (DFM) - PCB |  | 4d | 2012-05-21 | 2012-05-25 | 90, 94, 109 | 0d |  | ENGR; Project Manager | 32h | 1,840 |  |
| 111 | 1.3.2.5 | Approve |  | 1d | 2012-05-28 | 2012-05-28 | 109, 110 | 0d |  | Project Manager | 8h | 480 | PCB DESIGN READY |
| 112 | 1.3.2.6 | PCB Fabrication |  | 8d | 2012-05-29 | 2012-06-07 | 111 | 0d |  | PCB Fabricator | 64h | 2,560 | PCB PROTOTYPE |
| 113 | 1.3.3 | **Housing** |  | 77d | 2012-03-16 | 2012-07-02 |  | 7d |  |  | 296h | 19,240 |  |
| 114 | 1.3.3.1 | **Industrial Design** |  | 16d | 2012-03-27 | 2012-04-17 |  | 0d |  |  | 128h | 10,240 |  |
| 115 | 1.3.3.1.1 | Review & Approval |  | 16d | 2012-03-27 | 2012-04-17 | 18 | 0d |  | CONSULTANT | 128h | 10,240 |  |
| 116 | 1.3.3.2 | **Mechanical Design** |  | 12d | 2012-04-18 | 2012-05-03 |  | 0d |  |  | 96h | 4,800 |  |
| 117 | 1.3.3.2.1 | 3D CAD |  | 5d | 2012-04-18 | 2012-04-24 | 115 | 0d |  | Mechanical ENGR | 40h | 2,000 |  |
| 118 | 1.3.3.2.2 | Design Review |  | 1d | 2012-04-25 | 2012-04-25 | 117 | 0d |  | Mechanical ENGR | 8h | 400 |  |
| 119 | 1.3.3.2.3 | DFM |  | 2d | 2012-04-26 | 2012-04-27 | 118 | 0d |  | Mechanical ENGR | 16h | 800 |  |
| 120 | 1.3.3.2.4 | Approve | milestone | 0d | 2012-04-27 | 2012-04-27 | 119 | 0d |  | Mechanical ENGR; Project Manager |  |  |  |
| 121 | 1.3.3.2.5 | Part Drawings |  | 4d | 2012-04-30 | 2012-05-03 | 120 | 0d |  | Mechanical ENGR | 32h | 1,600 | MECH DESIGN |
| 122 | 1.3.3.3 | **Tooling** |  | 68d | 2012-03-16 | 2012-06-19 |  | 33d |  |  | 48h | 2,880 |  |
| 123 | 1.3.3.3.1 | Tooling Design |  | 2d | 2012-04-30 | 2012-05-01 | 120 | 2d | 0d | ODM/CM | 16h | 1,120 |  |
| 124 | 1.3.3.3.2 | Pre-lim tooling (T0) |  | 20d | 2012-05-04 | 2012-05-31 | 121, 123 | 0d |  |  |  |  |  |
| 125 | 1.3.3.3.3 | Final tooling (T1) |  | 13d | 2012-06-01 | 2012-06-19 | 124 | 0d |  |  |  |  | TOOLING COMPLETE |
| 126 | 1.3.3.3.4 | **Capacity Plan** |  | 1d | 2012-05-02 | 2012-05-02 |  | 86d |  |  | 16h | 880 |  |
| 127 | 1.3.3.3.4.1 | Review & Approval |  | 1d | 2012-05-02 | 2012-05-02 | 123 | 86d |  | Product ENGR; Operations | 16h | 880 |  |
| 128 | 1.3.3.3.5 | **Ramp-up Plan** |  | 1d | 2012-03-16 | 2012-03-16 |  | 119d |  |  | 16h | 880 |  |
| 129 | 1.3.3.3.5.1 | Review & Approval |  | 1d | 2012-03-16 | 2012-03-16 | 14 | 119d |  | Product ENGR; Operations | 16h | 880 |  |
| 130 | 1.3.3.4 | Housing Approved |  | 3d | 2012-06-28 | 2012-07-02 | 120, 125 | 0d |  | ENGR | 24h | 1,320 | MP HOUSING DONE |

| ID | WBS | Task | Type | Duration | Start | Finish | Predecessors | Total slack | Free slack | Resources | Work | Cost | Deliverable |
| --- | --- | --- | --- | --- | --- | --- | --- | --- | --- | --- | --- | --- | --- |
| 131 | 1.3.4 | **Packaging** |  | 88d | 2012-02-23 | 2012-06-25 |  | 48d |  |  | 464h | 23,360 |  |
| 132 | 1.3.4.1 | **Dummy** |  | 14d | 2012-05-04 | 2012-05-23 |  | 37d |  |  |  |  |  |
| 133 | 1.3.4.1.1 | Dummy Unit /Evaluate Button Functionality |  | 10d | 2012-05-04 | 2012-05-17 | 121 | 37d | 0d |  |  |  |  |
| 134 | 1.3.4.1.2 | Dummy Review and Approval |  | 4d | 2012-05-18 | 2012-05-23 | 133 | 37d | 0d |  |  |  |  |
| 135 | 1.3.4.2 | **Clamshell** |  | 37d | 2012-05-04 | 2012-06-25 |  | 38d |  |  | 312h | 15,920 |  |
| 136 | 1.3.4.2.1 | Clamshell Design |  | 3d | 2012-05-21 | 2012-05-23 | 65, 120 | 37d | 0d | Packaging ENGR | 24h | 1,200 | CLAMSHELL DESIGN |
| 137 | 1.3.4.2.2 | Clamshell Prototype Tool 20 units |  | 7d | 2012-05-24 | 2012-06-01 | 134, 136 | 37d | 0d | Packaging ENGR | 56h | 2,800 |  |
| 138 | 1.3.4.2.3 | FAI/Review & approval (Shipping included) |  | 4d | 2012-06-06 | 2012-06-11 | 137 | 37d | 0d | Packaging ENGR | 32h | 1,600 |  |
| 139 | 1.3.4.2.4 | Production Tool 20 units |  | 6d | 2012-06-12 | 2012-06-19 | 138 | 37d | 0d | Packaging ENGR | 48h | 2,400 |  |
| 140 | 1.3.4.2.5 | FAI/Review & Approval |  | 4d | 2012-06-20 | 2012-06-25 | 139 | 37d | 0d | Packaging ENGR | 32h | 1,600 | CLAMSHELL APPR'D |
| 141 | 1.3.4.2.6 | **Insert** |  | 15d | 2012-05-04 | 2012-05-24 |  | 60d |  |  | 120h | 6,320 |  |
| 142 | 1.3.4.2.6.1 | Clamshell Insert Design |  | 4d | 2012-05-04 | 2012-05-09 | 65, 120 | 60d | 0d | Packaging ENGR | 32h | 1,600 | INSERT DESIGN |
| 143 | 1.3.4.2.6.2 | Clamshell Insert Production Items |  | 7d | 2012-05-10 | 2012-05-18 | 142 | 60d | 0d | Packaging ENGR | 56h | 2,800 |  |
| 144 | 1.3.4.2.6.3 | FAI Review & Approval |  | 4d | 2012-05-21 | 2012-05-24 | 143 | 60d | 0d | Product MKTG | 32h | 1,920 | INSERT APPR'D |
| 145 | 1.3.4.3 | User Guide | milestone | 0d | 2012-03-21 | 2012-03-21 | 65 | 116d |  | Packaging ENGR |  |  |  |
| 146 | 1.3.4.4 | Insert Design | milestone | 0d | 2012-03-21 | 2012-03-21 | 65 | 116d |  | Packaging ENGR |  |  |  |
| 147 | 1.3.4.5 | **QSG** |  | 59d | 2012-02-23 | 2012-05-15 |  | 77d |  |  | 64h | 3,520 |  |
| 148 | 1.3.4.5.1 | QSG Copy | milestone | 0d | 2012-02-23 | 2012-02-23 |  | 124d | 47d | Product Manager |  |  |  |
| 149 | 1.3.4.5.2 | QSG Design |  | 4d | 2012-04-30 | 2012-05-03 | 65, 120, 148 | 77d | 0d | Packaging ENGR | 32h | 1,600 | QSG DESIGN |
| 150 | 1.3.4.5.3 | QSG Productions Items |  | 4d | 2012-05-04 | 2012-05-09 | 149 | 77d | 0d |  |  |  |  |
| 151 | 1.3.4.5.4 | FAI Review & Approval |  | 4d | 2012-05-10 | 2012-05-15 | 150 | 77d |  | Product Manager | 32h | 1,920 | QSG APPR'D |
| 152 | 1.3.4.6 | Collateral Design | milestone | 0d | 2012-03-21 | 2012-03-21 | 65 | 106d | 0d | Packaging ENGR |  |  |  |
| 153 | 1.3.4.7 | Label Design | milestone | 0d | 2012-03-21 | 2012-03-21 | 65 | 106d | 0d | Packaging ENGR |  |  | LABEL DESIGN |
| 154 | 1.3.4.8 | Retail Box Design | milestone | 0d | 2012-03-21 | 2012-03-21 | 65 | 106d | 0d | Packaging ENGR |  |  | BOX DESIGN |

| ID | WBS | Task | Type | Duration | Start | Finish | Predecessors | Complete | Total slack | Free slack | Resources | Work | Actual work | Cost | Actual cost | Deliverable |
| --- | --- | --- | --- | --- | --- | --- | --- | --- | --- | --- | --- | --- | --- | --- | --- | --- |
| 155 | 1.3.4.9 | **Shipping Corrugate** |  | 27d | 2012-04-27 | 2012-06-05 |  |  | 62d |  |  | 88h |  | 3,920 |  |  |
| 156 | 1.3.4.9.1 | Shipping Corugate Design | milestone | 0d | 2012-04-27 | 2012-04-27 | 65, 120 |  | 89d |  | Packaging ENGR |  |  |  |  |  |
| 157 | 1.3.4.9.2 | Production samples |  | 5d | 2012-05-28 | 2012-06-01 | 137FF |  | 52d | 0d | Outside vendor | 40h |  | 1,200 |  |  |
| 158 | 1.3.4.9.3 | FAI Review & Approval |  | 2d | 2012-06-04 | 2012-06-05 | 157 |  | 52d | 0d | Packaging ENGR; Project Manager; Product Manager | 48h |  | 2,720 |  |  |
| 159 | 1.3.5 | **BOM** |  | 2d | 2012-03-16 | 2012-03-19 |  |  | 107d |  |  | 32h |  | 1,840 |  |  |
| 160 | 1.3.5.1 | Marketing Pre-lim BOM |  | 1d | 2012-03-16 | 2012-03-16 | 14 |  | 119d |  | Product Manager; Project Manager | 16h |  | 960 |  | SKU APPR'D |
| 161 | 1.3.5.2 | Engineering Pre-lim BOM |  | 2d | 2012-03-16 | 2012-03-19 | 14 |  | 107d | 86d | ENGR | 16h |  | 880 |  | BOM APPR'D |
| 162 | 1.3.6 | **Pre-planning** |  | 2d | 2012-02-27 A | 2012-02-28 A |  | 100% |  |  |  | 32h | 32h | 2,560 | 2,560 |  |
| 163 | 1.3.6.1 | Pre-lim Forecast Frozen |  | 1d | 2012-02-27 A | 2012-02-27 A | 5 | 100% |  |  | VP of MKTG; Product Manager | 16h | 16h | 1,280 | 1,280 |  |
| 164 | 1.3.6.2 | Pre-lim-Forecast in Oracle |  | 1d | 2012-02-28 A | 2012-02-28 A | 163 | 100% |  |  | VP of MKTG; Product Manager | 16h | 16h | 1,280 | 1,280 |  |
| 165 | 1.3.7 | **Engineering Validation Test (EVT)** |  | 15d | 2012-06-01 | 2012-06-21 |  |  | 0d |  |  | 80h |  | 4,160 |  |  |
| 166 | 1.3.7.1 | T0 Mechanical |  | 1d | 2012-06-01 | 2012-06-01 | 124 |  | 4d |  | Product ENGR | 8h |  | 400 |  |  |
| 167 | 1.3.7.2 | EVT prototypes 2 units |  | 5d | 2012-06-08 | 2012-06-15 | 112, 166 |  | 0d |  | Product ENGR | 40h |  | 2,000 |  |  |
| 168 | 1.3.7.3 | Engineering Validation Testing |  | 3d | 2012-06-18 | 2012-06-20 | 167 |  | 0d |  | ENGR | 24h |  | 1,320 |  |  |
| 169 | 1.3.7.4 | Approve |  | 1d | 2012-06-21 | 2012-06-21 | 168 |  | 0d |  | ENGR | 8h |  | 440 |  | EVT APPR'D |
| 170 | 1.3.8 | **Design Validation Test (DVT)** |  | 50d | 2012-06-22 | 2012-08-30 |  |  | 0d |  |  | 448h |  | 22,920 |  |  |
| 171 | 1.3.8.1 | Changes from EVT |  | 5d | 2012-06-22 | 2012-07-03 | 169 |  | 0d |  | ENGR | 40h |  | 2,200 |  |  |
| 172 | 1.3.8.2 | T1 Mechanical |  | 1d | 2012-07-03 | 2012-07-03 | 130 |  | 0d |  | Product ENGR | 8h |  | 400 |  |  |
| 173 | 1.3.8.3 | DVT prototypes 10 units |  | 5d | 2012-07-04 | 2012-07-10 | 171, 172 |  | 0d |  | Product ENGR | 40h |  | 2,000 |  |  |
| 174 | 1.3.8.4 | Design Validation Testing |  | 7d | 2012-07-19 | 2012-08-01 | 173 |  | 11d | 10d | ENGR | 56h |  | 3,080 |  | DVT APPR'D |
| 175 | 1.3.8.5 | **PCB Qualification** |  | 37d | 2012-07-11 | 2012-08-30 |  |  | 0d |  |  | 296h |  | 14,800 |  |  |
| 176 | 1.3.8.5.1 | EMI |  | 5d | 2012-07-11 | 2012-07-17 | 173 |  | 0d |  | Outside Cert Lab | 40h |  | 2,000 |  |  |
| 177 | 1.3.8.5.2 | ESD | milestone | 0d | 2012-07-17 | 2012-07-17 | 176 |  | 1d | 0d | Outside Cert Lab |  |  |  |  |  |
| 178 | 1.3.8.5.3 | FCC | milestone | 0d | 2012-07-17 | 2012-07-17 | 177 |  | 32d |  | Outside Cert Lab |  |  |  |  |  |
| 179 | 1.3.8.5.4 | USB IF |  | 10d | 2012-08-02 | 2012-08-15 | 176 |  | 11d |  | Outside Cert Lab | 80h |  | 4,000 |  |  |
| 180 | 1.3.8.5.5 | WHQL |  | 11d | 2012-08-16 | 2012-08-30 | 176 |  | 0d |  | Outside Cert Lab | 88h |  | 4,400 |  |  |
| 181 | 1.3.8.5.6 | Certificate |  | 11d | 2012-07-18 | 2012-08-01 | 177 |  | 21d |  | Outside Cert Lab | 88h |  | 4,400 |  |  |
| 182 | 1.3.8.6 | Approve |  | 1d | 2012-07-18 | 2012-07-18 | 176, 177 |  | 1d | 0d | ENGR | 8h |  | 440 |  | ALL CERTS DONE |

| ID | WBS | Task | Type | Duration | Start | Finish | Predecessors | Remaining | Total slack | Free slack | Resources | Work | Cost | Deliverable |
| --- | --- | --- | --- | --- | --- | --- | --- | --- | --- | --- | --- | --- | --- | --- |
| 183 | 1.3.9 | **Phase 2 gate** |  | 2d | 2012-07-19 | 2012-07-20 |  |  | 27d |  |  | 32h | 2,560 |  |
| 184 | 1.3.9.1 | Review & Approval |  | 2d | 2012-07-19 | 2012-07-20 | 54, 105, 182 |  | 27d | 20d | Project Manager; VP of MKTG | 32h | 2,560 |  |
| 185 | 1.4 | **Phase 3 (Qualification)** |  | 109d | 2012-03-21 A | 2012-08-21 |  | 109d | 7d |  |  | 528h | 637,640 |  |
| 186 | 1.4.1 | **Packaging** |  | 69d | 2012-03-21 A | 2012-06-26 |  | 69d | 47d |  |  | 128h | 8,320 |  |
| 187 | 1.4.1.1 | Die Lines (all components) | milestone | 0d | 2012-03-21 | 2012-03-21 | 65 |  | 102d | 0d | Packaging ENGR |  |  |  |
| 188 | 1.4.1.2 | **Clamshell** |  | 20d | 2012-05-29 A | 2012-06-26 |  | 20d | 47d |  |  |  |  |  |
| 189 | 1.4.1.2.1 | Prototype Sample delivery & approval | milestone | 0d | 2012-06-11 | 2012-06-11 | 138 |  | 58d |  | Packaging ENGR |  |  |  |
| 190 | 1.4.1.2.2 | Production samples (20 units) |  | 1d | 2012-05-29 A | 2012-06-26 | 140 | 1d | 37d | 0d |  |  |  |  |
| 191 | 1.4.1.2.3 | FA Review & Approval | milestone | 0d | 2012-06-26 | 2012-06-26 | 190 |  | 37d | 0d | Product Manager; Project Manager |  |  | CLAMSHELL FA APPR'D |
| 192 | 1.4.1.3 | **Clamshell Insert** |  | 0d | 2012-05-24 | 2012-05-24 |  |  | 60d |  |  |  |  |  |
| 193 | 1.4.1.3.1 | FA Review & Approval | milestone | 0d | 2012-05-24 | 2012-05-24 | 144 |  | 60d | 23d | Product Manager; Project Manager |  |  | CLAM INS FA APPR'D |
| 194 | 1.4.1.4 | **Collateral** |  | 0d | 2012-03-21 | 2012-03-21 |  |  | 106d |  |  |  |  |  |
| 195 | 1.4.1.4.1 | FA Review & Approval | milestone | 0d | 2012-03-21 | 2012-03-21 | 152 |  | 106d | 69d | Product Manager; Project Manager |  |  | QSG FA APPR'D |
| 196 | 1.4.1.5 | **Labels** |  | 0d | 2012-03-21 | 2012-03-21 |  |  | 106d |  |  |  |  |  |
| 197 | 1.4.1.5.1 | FA Review & Approval | milestone | 0d | 2012-03-21 | 2012-03-21 | 153 |  | 106d | 69d | Product Manager; Project Manager |  |  | LABEL FA APPR'D |
| 198 | 1.4.1.6 | **Retail Box Artwork** |  | 0d | 2012-03-21 | 2012-03-21 |  |  | 106d |  |  |  |  |  |
| 199 | 1.4.1.6.1 | FA Review & Approval | milestone | 0d | 2012-03-21 | 2012-03-21 | 154 |  | 106d | 0d | Product Manager; Project Manager |  |  | PRODUCT BOX APPR'D |
| 200 | 1.4.1.7 | **FG Box** |  | 0d | 2012-03-21 | 2012-03-21 |  |  | 106d |  |  |  |  |  |
| 201 | 1.4.1.7.1 | FA Review & Approval | milestone | 0d | 2012-03-21 | 2012-03-21 | 199 |  | 106d | 69d | Product Manager; Project Manager |  |  | FG BOX FA APPR'D |
| 202 | 1.4.1.8 | **Shipping Corrugate** |  | 0d | 2012-06-05 | 2012-06-05 |  |  | 52d |  |  |  |  |  |
| 203 | 1.4.1.8.1 | FA Review & Approval | milestone | 0d | 2012-06-05 | 2012-06-05 | 158 |  | 52d | 15d | Product Manager; Project Manager |  |  | CORRUGATE FA APPR'D |
| 204 | 1.4.1.9 | **Package Qualification** |  | 14d | 2012-03-22 | 2012-04-10 |  |  | 102d |  |  | 128h | 8,320 |  |
| 205 | 1.4.1.9.1 | **Packaging Test** |  | 12.5d | 2012-03-22 | 2012-04-09 |  |  | 102d | 0d |  | 104h | 7,120 |  |
| 206 | 1.4.1.9.1.1 | Testing |  | 12d | 2012-03-22 | 2012-04-06 | 187 |  | 102d | 0d | ODM/CM | 96h | 6,720 |  |
| 207 | 1.4.1.9.1.2 | Report Review & Approval |  | 0.5d | 2012-04-09 | 2012-04-09 | 206 |  | 102d |  | Product ENGR; Packaging ENGR | 8h | 400 |  |

| ID | WBS | Task | Type | Duration | Start | Finish | Predecessors | Total slack | Free slack | Resources | Work | Cost | Deliverable |
| --- | --- | --- | --- | --- | --- | --- | --- | --- | --- | --- | --- | --- | --- |
| 208 | 1.4.1.9.2 | **Packaging Test Sample** |  | 1.5d | 2012-04-09 | 2012-04-10 |  | 102d |  |  | 24h | 1,200 |  |
| 209 | 1.4.1.9.2.1 | Review & Approval |  | 1.5d | 2012-04-09 | 2012-04-10 | 205 | 102d |  | Product ENGR; Packaging ENGR | 24h | 1,200 |  |
| 210 | 1.4.2 | All packaging Items approved | milestone | 0d | 2012-06-26 | 2012-06-26 | 187, 191, 193, 195, 197, 199, 201, 203 | 37d | 36d | Product Manager; Project Manager |  |  | ALL PACK APPR'D |
| 211 | 1.4.3 | **BOM** |  | 5d | 2012-06-06 | 2012-06-12 |  | 46d |  |  | 32h | 1,840 |  |
| 212 | 1.4.3.1 | Engineering PVT |  | 2d | 2012-06-06 | 2012-06-07 | 111 | 46d | 0d | ENGR | 16h | 880 | PVT RELEASE NOTICE |
| 213 | 1.4.3.2 | Marketing PVT |  | 2d | 2012-06-11 | 2012-06-12 | 212 | 48d | 28d | Product Manager | 16h | 960 |  |
| 214 | 1.4.4 | **Production Validation Test (PVT)** |  | 57d | 2012-05-29 | 2012-08-15 |  | 1d |  |  | 216h | 17,960 |  |
| 215 | 1.4.4.1 | **PVT Build** |  | 52d | 2012-05-29 | 2012-08-08 |  | 1d |  |  | 88h | 11,280 |  |
| 216 | 1.4.4.1.1 | **Material PO** |  | 1d | 2012-05-29 | 2012-05-29 | 111, 123 | 37d | 36d | Planning | 8h | 6,480 | PVT PO PLACED |
| 217 | 1.4.4.1.1.1 | NAND |  | 1d | 2012-05-29 | 2012-05-29 |  | 37d |  | NAND supplier [80000%] |  | 4,000 |  |
| 218 | 1.4.4.1.1.2 | PCB |  | 1d | 2012-05-29 | 2012-05-29 |  | 37d |  | PCB supplier [10000%] |  | 200 |  |
| 219 | 1.4.4.1.1.3 | Capacitors, resistors, diodes, transistors, etc |  | 1d | 2012-05-29 | 2012-05-29 |  | 37d |  | Passives supplier |  | 500 |  |
| 220 | 1.4.4.1.1.4 | Controller |  | 1d | 2012-05-29 | 2012-05-29 |  | 37d |  | CONtroller supplier [10000%] |  | 500 |  |
| 221 | 1.4.4.1.1.5 | Housing |  | 1d | 2012-05-29 | 2012-05-29 |  | 37d |  | Housing supplier [10000%] |  | 600 |  |
| 222 | 1.4.4.1.1.6 | Other |  | 1d | 2012-05-29 | 2012-05-29 |  | 37d |  | Other supplier [10000%] |  | 200 |  |
| 223 | 1.4.4.1.2 | Build 100 functional units |  | 10d | 2012-07-24 | 2012-08-08 | 182, 216 | 1d | 0d | Operations | 80h | 4,800 | PVT PO PLACED |
| 224 | 1.4.4.2 | **Samples** |  | 4d | 2012-08-09 | 2012-08-14 |  | 1d |  |  | 32h | 1,600 |  |
| 225 | 1.4.4.2.1 | Marketing Sample Delivery |  | 4d | 2012-08-09 | 2012-08-14 | 223 | 1d | 0d | Product ENGR | 32h | 1,600 |  |
| 226 | 1.4.4.2.2 | Preproduction Sample Delivery | milestone | 0d | 2012-08-14 | 2012-08-14 | 225 | 1d | 0d | Product ENGR |  |  |  |
| 227 | 1.4.4.3 | **FAI (unit without Mrktg Packaging)** |  | 1d | 2012-08-15 | 2012-08-15 |  | 1d |  |  | 16h | 960 |  |
| 228 | 1.4.4.3.1 | Review & Approve |  | 1d | 2012-08-15 | 2012-08-15 | 226 | 1d | 0d | Product Manager; Project Manager | 16h | 960 |  |
| 229 | 1.4.4.4 | **PVT Testing** |  | 17d | 2012-07-11 | 2012-08-02 |  | 10d |  |  | 80h | 4,120 |  |
| 230 | 1.4.4.4.1 | Mechanical Test |  | 7d | 2012-07-11 | 2012-07-19 | 173 | 11d | 0d | Product ENGR | 56h | 2,800 |  |
| 231 | 1.4.4.4.2 | Applications Compatibility Test | milestone | 0d | 2012-07-19 | 2012-07-19 | 230 | 11d | 0d | Product ENGR |  |  |  |
| 232 | 1.4.4.4.3 | Certification / Compliance Qual | milestone | 0d | 2012-07-19 | 2012-07-19 | 231 | 11d | 0d | Product ENGR |  |  |  |
| 233 | 1.4.4.4.4 | Product Reliability Qualification | milestone | 0d | 2012-07-19 | 2012-07-19 | 232 | 11d | 0d | Product ENGR |  |  |  |
| 234 | 1.4.4.4.5 | Yeild Analysis | milestone | 0d | 2012-07-19 | 2012-07-19 | 233 | 11d | 1d | Operations |  |  |  |
| 235 | 1.4.4.4.6 | PVT Testing approved |  | 3d | 2012-07-23 | 2012-08-02 | 231, 232, 233, 234 | 10d | 0d | ENGR | 24h | 1,320 | PVT APPR'D |

| ID | WBS | Task | Type | Duration | Start | Finish | Predecessors | Total slack | Free slack | Resources | Work | Cost | Deliverable |
| --- | --- | --- | --- | --- | --- | --- | --- | --- | --- | --- | --- | --- | --- |
| 236 | 1.4.5 | **FAI - Production Samples FG** |  | 1d | 2012-08-16 | 2012-08-16 |  | 1d |  |  | 8h | 480 |  |
| 237 | 1.4.5.1 | FA Review & Approval |  | 1d | 2012-08-16 | 2012-08-16 | 169, 174, 182, 210, 228, 235 | 1d | 0d | Product Manager | 8h | 480 |  |
| 238 | 1.4.6 | **CM/ODM Readiness** |  | 101d | 2012-03-23 | 2012-08-10 |  | 14d |  |  | 96h | 605,560 |  |
| 239 | 1.4.6.1 | Final Forecast |  | 1d | 2012-03-23 | 2012-03-23 | 90, 164 | 114d |  | Operations | 8h | 480 |  |
| 240 | 1.4.6.2 | Hand Off Packet |  | 5d | 2012-08-06 | 2012-08-10 | 223SF-1d | 14d |  | ENGR | 40h | 2,200 |  |
| 241 | 1.4.6.3 | Materials locked in for ISO (Components - PCB, Memory, Controllers, Housing) |  | 1d | 2012-07-18 | 2012-07-18 | 161, 177 | 21d | 0d | Operations | 8h | 480 | BOM COMPONENTS IN |
| 242 | 1.4.6.4 | **PO for ISO Builds** |  | 1d | 2012-07-19 | 2012-07-19 | 97, 108, 241 | 21d | 0d | Operations | 8h | 600,480 | MP PO PLACED |
| 243 | 1.4.6.4.1 | NAND |  | 1d | 2012-07-19 | 2012-07-19 |  | 21d |  | NAND supplier |  | 400,000 |  |
| 244 | 1.4.6.4.2 | PCB |  | 1d | 2012-07-19 | 2012-07-19 |  | 21d |  | PCB supplier |  | 20,000 |  |
| 245 | 1.4.6.4.3 | Capacitors, resistors, diodes, transistors, etc |  | 1d | 2012-07-19 | 2012-07-19 |  | 21d |  | Passives supplier |  | 50,000 |  |
| 246 | 1.4.6.4.4 | Controller |  | 1d | 2012-07-19 | 2012-07-19 |  | 21d |  | CONtroller supplier |  | 50,000 |  |
| 247 | 1.4.6.4.5 | Housing |  | 1d | 2012-07-19 | 2012-07-19 |  | 21d |  | Housing supplier |  | 60,000 |  |
| 248 | 1.4.6.4.6 | Other |  | 1d | 2012-07-19 | 2012-07-19 |  | 21d |  | Other supplier |  | 20,000 |  |
| 249 | 1.4.6.5 | W/O |  | 1d | 2012-07-20 | 2012-07-20 | 242 | 24d | 0d | Operations | 8h | 480 |  |
| 250 | 1.4.6.6 | ISO Builds (10,000pcs) |  | 1d | 2012-07-23 | 2012-07-23 | 213, 249 | 24d | 8d | Operations | 8h | 480 | MP BUILD COMPLETE |
| 251 | 1.4.6.7 | Ramp-up |  | 1d | 2012-08-03 | 2012-08-03 | 94, 235, 250 | 16d | 0d | Operations | 8h | 480 |  |
| 252 | 1.4.6.8 | Work Sheet Approved |  | 1d | 2012-08-06 | 2012-08-06 | 251 | 16d | 9d | Operations | 8h | 480 |  |
| 253 | 1.4.7 | **BOM** |  | 1d | 2012-08-17 | 2012-08-17 |  | 7d |  |  | 16h | 920 |  |
| 254 | 1.4.7.1 | Release Notes for Engineering BOM and Marketing BOM |  | 1d | 2012-08-17 | 2012-08-17 | 235, 237 | 7d | 0d | ENGR; Product Manager | 16h | 920 |  |
| 255 | 1.4.8 | **Phase 3 gate** |  | 2d | 2012-08-20 | 2012-08-21 |  | 7d |  |  | 32h | 2,560 |  |
| 256 | 1.4.8.1 | Review & Approve |  | 2d | 2012-08-20 | 2012-08-21 | 184, 237, 252, 254 | 7d |  | Project Manager; VP of MKTG | 32h | 2,560 |  |
| 257 | 1.5 | **Phase 4 (Production)** |  | 9d | 2012-08-16 | 2012-08-29 |  | 1d |  |  | 72h | 4,320 |  |
| 258 | 1.5.1 | FG Launch Buiild | milestone | 0d | 2012-08-16 | 2012-08-16 | 213, 235, 237, 241, 242 | 1d | 0d | Operations; ENGR |  |  |  |
| 259 | 1.5.2 | Taiwan |  | 3d | 2012-08-17 | 2012-08-21 | 258 | 1d | 0d | Operations | 24h | 1,440 | TWN FG |
| 260 | 1.5.3 | NA |  | 3d | 2012-08-27 | 2012-08-29 | 259 | 1d |  | Operations | 24h | 1,440 | US FG |
| 261 | 1.5.4 | EU |  | 3d | 2012-08-22 | 2012-08-24 | 259 | 4d | 0d | Operations | 24h | 1,440 | EU FG |
| 262 | 1.5.5 | Mass-Production | milestone | 0d | 2012-08-24 | 2012-08-24 | 261 | 4d |  | Operations |  |  | PROJECT COMPLETE |
